# 3GPP_Release-2000

Schedule from MS Project, 2000-01-03 to 2008-11-21, A marks actual dates.

## Calendars

- Standard: Mon-Fri 08:00-12:00, 13:00-17:00; Sat-Sun off.

## Resources

| Resource |
| --- |
| NP |
| N1 |
| N2 |
| N3 |
| N4 |
| N5 |
| TP |
| T1 |
| T2 |
| T3 |
| RP |
| R1 |
| R2 |
| R3 |
| R4 |
| SP |
| S1 |
| S2 |
| S3 |
| S4 |
| S5 |
| PCG |
| GP |
| No |
| CN4 |
| ? |
| WG G2 |
| G2 |
| G1 |
| G4 |
| G3 |
| All |
| Generic |
| MLST |
| G5 |
| S3; G2 |
| WG T2 |
| GP;G1 |
| G4;G5 |
| OMA |
| GP-G2 |
| Yes |
| GP; |
| N4; |
| GP; N1 |
| CT5 |
| C5 |
| C1 |
| C4 |
| C3 |
| C6 |
| G1; |
| 4 |
| ct |
| c;s;r |
| CT,RAN,SA |
| G2, |
| G1, G3 |
| CT6 |
| CT1 |
| CT1, CT3, CT4 |
| C1, C3, C4 |
| CP |

## Schedule

| ID | WBS | Task | Type | Duration | Start | Finish | Complete | Baseline start | Baseline finish | Baseline duration | Total slack | Constraint | Resources | Work | Actual work | Text9 | Text6 | Text1 | Text4 | Text5 | Text7 | Text8 | Text12 |
| --- | --- | --- | --- | --- | --- | --- | --- | --- | --- | --- | --- | --- | --- | --- | --- | --- | --- | --- | --- | --- | --- | --- | --- |
| 1 | 1 | VERSION 2008 April 21th |  | 1d | 2000-01-03 | 2000-01-03 |  | 2000-01-03 | 2000-01-03 | 1d | 2319d | start no earlier than 2000-01-01 |  |  |  | 2044 |  |  |  |  |  |  |  |
| 2 | 2 | "CTRL + a" to display all the 3GPP fields |  | 1d | 2000-01-03 | 2000-01-03 |  | 2000-01-03 | 2000-01-03 | 1d | 2319d | start no earlier than 2000-01-01 |  |  |  | 1462 |  |  |  |  |  |  |  |
| 3 | 3 | Content of Rel-7 (frozen) |  | 1d | 2000-01-03 | 2000-01-03 |  | 2000-01-03 | 2000-01-03 | 1d | 2319d | start no earlier than 2000-01-01 |  |  |  | 2058 |  |  |  |  |  |  |  |
| 5 | 4 | Rel-7 Features |  | 1d? | 2000-01-03 | 2000-01-03 |  | 2000-01-03 | 2000-01-03 | 1d? | 2319d | start no earlier than 2000-01-01 | CT,RAN,SA | 8h |  |  | Rel-7 |  |  |  |  |  |  |
| 6 | 8.5 | **Multiple Input Multiple Output antennas (MIMO)** |  | 1177d? | 2003-03-14 A | 2007-09-17 A | 100% | 2003-03-14 | 2007-06-04 | 1102d? |  |  | R1 | 40272h | 40272h | 2468 | Rel-7 | MIMO | Howard Huang, Alcatel-Lucent | hchuang@Alcatel-Lucent.com | TSG | Claude |  |
| 7 | 5.1 | MIMO - Physical layer |  | 915d? | 2003-09-12 A | 2007-03-15 A | 100% | 2003-09-12 | 2007-03-15 | 915d? |  | finish no earlier than 2007-03-15 | R1 | 7320h | 7320h |  | Rel-7 | MIMO-Phys | Howard Huang, Alcatel-Lucent | hchuang@Alcatel-Lucent.com | TSG | MCC_RAN |  |
| 8 | 5.2 | MIMO - Layer 2,3 aspects |  | 915d? | 2003-09-12 A | 2007-03-15 A | 100% | 2003-09-12 | 2007-03-15 | 915d? |  | finish no earlier than 2007-03-15 | R2 | 7320h | 7320h |  | Rel-7 | MIMO-L23 | Howard Huang, Alcatel-Lucent | hchuang@Alcatel-Lucent.com | TSG | MCC_RAN |  |
| 9 | 5.3 | MIMO - Iub/Iur Protocol Aspects |  | 1045d? | 2003-03-14 A | 2007-03-15 A | 100% | 2003-03-14 | 2007-03-15 | 1045d? |  | finish no earlier than 2007-03-15 | R3 | 8360h | 8360h |  | Rel-7 | MIMO-IurIub | Howard Huang, Alcatel-Lucent | hchuang@Alcatel-Lucent.com | TSG | MCC_RAN |  |
| 10 | 5.4 | MIMO - RF Radio Transmission/Reception, System Performance Requirements and Conformance Testing |  | 982d? | 2003-12-12 A | 2007-09-17 A | 100% | 2003-12-12 | 2007-06-04 | 907d? |  | finish no earlier than 2007-09-17 | R4 | 7856h | 7856h |  | Rel-7 | MIMO-RF | Man Hung Ng, Alcatel-Lucent | ngm@Alcatel-Lucent.com | TSG | MCC_RAN |  |
| 11 | 6 | **Rel-7 Improvements of the Radio Interface** |  | 709d? | 2004-09-15 A | 2007-06-04 A | 100% | 2004-09-15 | 2007-06-15 | 718d? |  |  | RP | 29696h | 29696h |  | Rel-7 | RInImp |  |  |  | Claude |  |
| 12 | 6.1 | Extended UMTS 1.7/2.1 GHz |  | 198d? | 2006-03-15 A | 2006-12-15 A | 100% | 2006-03-15 | 2006-12-15 | 198d? |  | finish no earlier than 2006-12-15 | R4 | 1584h | 1584h |  | Rel-7 | RInImp-UMTS1721Ext | Johan Sköld | johan.skold@ericsson.com |  | MCC_RAN |  |
| 13 | 6.2 | UMTS 2.6 GHz 7.68 MHz TDD |  | 67d? | 2006-06-15 A | 2006-09-15 A | 100% | 2006-06-15 | 2006-09-15 | 67d? |  | finish no earlier than 2006-09-15 | R4 | 536h | 536h |  | Rel-7 | RInImp-UMTS26VHCRTDD | Shin Horng Wong , IPWireless | shwong@ipwireless.com |  | MCC_RAN |  |
| 14 | 6.3 | UMTS 2.6 GHz |  | 195d? | 2004-09-15 A | 2005-06-14 A | 100% | 2004-09-15 | 2005-06-14 | 195d? |  | finish no earlier than 2005-06-14 | R4 | 1560h | 1560h |  | Rel-7 | RInImp-UMTS2600 | Jussi Numminen, Nokia | jussi.numminen@nokia.com | TSG | Claude |  |
| 15 | 6.4 | UMTS 2.6 GHz TDD |  | 261d? | 2004-12-15 A | 2005-12-14 A | 100% | 2004-12-15 | 2005-12-14 | 261d? |  | finish no earlier than 2005-12-15 | R4 | 2088h | 2088h |  | Rel-7 | RInImp-UMTS2600TDD | Shin Horng Wong (IPWireless) | shwong@IPWIRELESS.COM | TSG | MCC_RAN |  |
| 16 | 6.5 | UMTS 900 MHz |  | 261d? | 2004-12-15 A | 2005-12-14 A | 100% | 2004-12-15 | 2005-12-14 | 261d? |  | finish no earlier than 2005-12-15 | R4 | 2088h | 2088h |  | Rel-7 | RInImp-UMTS900 | Yannick Li (Nortel) | yli@nortelnetworks.com | TSG | MCC_RAN |  |
| 17 | 6.6 | UMTS 1700 MHz |  | 197d? | 2005-03-15 A | 2005-12-14 A | 100% | 2005-03-15 | 2005-12-14 | 197d? |  | finish no earlier than 2005-12-15 | R4 | 1576h | 1576h |  | Rel-7 | RInImp-UMTS1700 | Takehiro Nakamura | NTT DoCoMo | TSG | MCC_RAN |  |
| 18 | 6.7 | closed - UE Antenna Performance Evaluation Method and Requirements |  | 644d? | 2004-12-15 A | 2007-06-04 A | 100% | 2004-12-15 | 2007-06-04 | 644d? |  | finish no earlier than 2007-06-04 | R4 | 5152h | 5152h |  | Rel-7 | RInImp-UEAnt | Christian Bergljung (TeliaSonera) | Christian.Bergljung@TeliaSonera.com | TSG | MCC_RAN |  |
| 19 | 6.8 | Improved Performance Requirements for HSDPA UE based on Rx Diversity (type 1) & LMMSE equalizer (type 2) | milestone | 0d? | 2005-03-15 A | 2005-03-15 A | 100% | 2005-03-15 | 2005-03-15 | 0d? |  | finish no earlier than 2005-03-15 | R4 |  |  |  | Rel-7 | RInImp-HSPerf-Type3 | Marc Grant | marc.grant@cingular.com | TSG | MCC_RAN |  |
| 20 | 6.9 | **Additional minimum UE performance requirement for non-HSDPA channels based on type 1 enhanced receiver (Rx Diversity)** |  | 327d? | 2005-09-15 A | 2006-12-15 A | 100% | 2005-09-15 | 2006-12-15 | 327d? |  |  | R4 | 7344h | 7344h |  | Rel-7 | RInImp-RxDiv | Serge Willenegger | sergew@qualcomm.com |  | MCC_RAN |  |
| 21 | 6.9.1 | Additional minimum UE performance requirement for DL physical channels in support of DCH/HS-DSCH operation based on type 1 enhanced receiver (RX-Diversity) |  | 195d? | 2005-09-15 A | 2006-06-14 A | 100% | 2005-09-15 | 2006-06-14 | 195d? |  | finish no earlier than 2006-06-15 | R4 | 1560h | 1560h |  | Rel-7 | RInImp-RxDiv-DCH | Marc Grant | marc.grant@cingular.com | TSG | MCC_RAN |  |
| 22 | 6.9.2 | Additional minimum UE performance requirement for downlink physical channels in support of MTCH and MCCH operation based on type 1 enhanced receiver (Rx-Diversity) |  | 198d? | 2006-03-15 A | 2006-12-15 A | 100% | 2006-03-15 | 2006-12-15 | 198d? |  | finish no earlier than 2006-12-15 | R4 | 1584h | 1584h |  | Rel-7 | RInImp-RxDiv-MBMS | Serge Willenegger | sergew@qualcomm.com |  | MCC_RAN |  |
| 23 | 6.9.3 | Additional minimum UE performance requirement for downlink physical channels in support of E-DCH operation based on type 1 enhanced receiver (Rx-Diversity) |  | 198d? | 2006-03-15 A | 2006-12-15 A | 100% | 2006-03-15 | 2006-12-15 | 198d? |  | finish no earlier than 2006-12-15 | R4 | 1584h | 1584h |  | Rel-7 | RInImp-RxDiv-EDCH | Serge Willenegger | sergew@qualcomm.com |  | MCC_RAN |  |
| 24 | 6.10 | Improved support of gaming over HSDPA/EDCH |  | 262d? | 2005-12-15 A | 2006-12-15 A | 100% | 2005-12-15 | 2006-12-15 | 262d? |  | finish no earlier than 2006-12-15 | R2 | 2096h | 2096h |  | Rel-7 | RInImp-Gaming | Don Zelmer, Cingular | don.zelmer@cingular.com |  | MCC_RAN |  |
| 25 | 6.11 | Deleted (not approved at PCG) - UMTS 2.6 GHz FDD DL External | milestone | 0d? | 2005-09-15 A | 2005-09-15 A | 100% | 2005-09-15 | 2005-09-15 | 0d? |  | finish no earlier than 2005-09-15 | R4 |  |  |  | Rel-7 | RInImp-UMTS2600Ext | Han van Bussel | han.van.bussel@t-mobile.de | TSG | MCC_RAN | RP-31 |

Notes:
- 6: hchuang@Alcatel-Lucent.com / Text3: TR25.876,TR25.996
- 7: hchuang@Alcatel-Lucent.com / Text3: 25.211, 25.212, 25.213, 25.214, 25.215, 25.221, 25
- 8: hchuang@Alcatel-Lucent.com / Text3: TR 25.876
- 9: hchuang@Alcatel-Lucent.com
- 10: ngm@Alcatel-Lucent.com
- 12: Approved at RP#34 as RP-060681 / Text3: 25.806, 25.101, 25.104, 25.133, 24.141, 25.331, 25.306, 25.307, 25.423, 25.461, 25.463, 34.121
- 13: Approved at RP#33 as RP-060451 / Text3: 25.102, 25.105, 25.123, 25.113, 25.142, 34.124
- 14: Approved at RP#25 as RP-040377 / Text3: TS25.101, TS25.104, TS25.133, TS25.141, TS25.331, TS25.942, TS25.306, TS25.307, TS34.121
- 15: Text3: 25.102, 25.105, 25.113, 25.123, 25.142, 25.331, 25.942, 25.306, 25.307, 34.122, 34.124
- 16: Text3: 25.101, 25.104, 25.113, 25.133, 25.141, 25.331, 25.942, 25.306, 25.307, 34.121
- 17: Text3: 25.101, 25.104, 25.113, 25.133, 25.141, 25.306, 25.307, 25.331, 34.121
- 18: closed at 90% / Text3: TS25.101, TS 25.963
- 19: Text3: 25.101
- 21: Text3: 25.101
- 22: Approved at RP#34 as RP-060678 / Text3: 25.101
- 23: Approved at RP#34 as RP-060679 / Text3: 25.101
- 24: Closed at RP#34 as RP-060680
- 25: This item was conditionnaly approved pending decision of PCG 16 who decided not to approve it / Text3: 25.101, 25.104, 25.133, 25.141, 25.331, 25.942, 25.306, 25.307, 34.121

| ID | WBS | Task | Duration | Start | Finish | Complete | Baseline start | Baseline finish | Baseline duration | Constraint | Resources | Work | Actual work | Text1 | Text4 | Text5 | Text6 | Text7 | Text8 |
| --- | --- | --- | --- | --- | --- | --- | --- | --- | --- | --- | --- | --- | --- | --- | --- | --- | --- | --- | --- |
| 26 | 7 | **7.68Mcps TDD option** | 457d? | 2004-09-15 A | 2006-06-15 A | 100% | 2004-09-15 | 2006-06-15 | 457d? |  | RP | 19824h | 19824h | VHCRTDD | Martin Beale, IPWireless | mbeale@ipwireless.com | Rel-7 | TSG | Claude |
| 27 | 7.1 | VHCRTDD: Stage 2 | 391d? | 2004-09-15 A | 2006-03-15 A | 100% | 2004-09-15 | 2006-03-15 | 391d? | finish no earlier than 2006-03-15 | R1 | 3128h | 3128h | VHCRTDD-Stage2 | Martin Beale, IPWireless | mbeale@ipwireless.com | Rel-7 | TSG | MCC_RAN |
| 28 | 7.2 | VHCRTDD: Physical Layer | 391d? | 2004-09-15 A | 2006-03-15 A | 100% | 2004-09-15 | 2006-03-15 | 391d? | finish no earlier than 2006-03-15 | R1 | 3128h | 3128h | VHCRTDD-Phys | Martin Beale, IPWireless | mbeale@ipwireless.com | Rel-7 | TSG | MCC_RAN |
| 29 | 7.3 | VHCRTDD: Layer 2 and layer 3 protocol aspects | 391d? | 2004-09-15 A | 2006-03-15 A | 100% | 2004-09-15 | 2006-03-15 | 391d? | finish no earlier than 2006-03-15 | R2 | 3128h | 3128h | VHCRTDD-L23 | Derek Richards, IPWireless | drichards@ipwireless.com | Rel-7 | TSG | MCC_RAN |
| 30 | 7.4 | VHCRTDD: UTRAN Iub/Iur Protocol Aspects | 391d? | 2004-09-15 A | 2006-03-15 A | 100% | 2004-09-15 | 2006-03-15 | 391d? | finish no earlier than 2006-03-15 | R3 | 3128h | 3128h | VHCRTDD-IurIub | Peter Legg, IPWireless | plegg@ipwireless.com | Rel-7 | TSG | MCC_RAN |
| 31 | 7.5 | VHCRTDD: RF Radio Transmission/ Reception, System Performance Requirements and Conformance Testing | 457d? | 2004-09-15 A | 2006-06-15 A | 100% | 2004-09-15 | 2006-06-15 | 457d? | finish no earlier than 2006-06-15 | R4 | 3656h | 3656h | VHCRTDD-RF | Shin Horng Wong | shwong@ipwireless.com | Rel-7 | TSG | MCC_RAN |
| 32 | 8 | **Rel-7 RAN improvements** | 653d? | 2004-12-15 A | 2007-06-15 A | 100% | 2004-12-15 | 2007-06-04 | 644d? |  | RP | 29104h | 29104h | RANimp |  |  | Rel-7 | TSG | MCC_RAN |
| 33 | 8.1 | Optimisation of channelisation code utilisation for 1.28 Mcps TDD | 523d? | 2004-12-15 A | 2006-12-15 A | 100% | 2004-12-15 | 2006-12-15 | 523d? | finish no earlier than 2006-12-15 | R1 | 4184h | 4184h | RANimp-RABSE-CodOptLCRTDD | Ka Leong Lo | kaleong.lo@utstar.com | Rel-7 | TSG | MCC_RAN |
| 34 | 8.2 | Delay optimisation for procedures applicable to CS and PS Connections | 394d? | 2005-03-15 A | 2006-09-15 A | 100% | 2005-03-15 | 2006-09-15 | 394d? | finish no earlier than 2006-09-15 | R2 | 3152h | 3152h | RANimp-DelayOpt | Juho Pirskanen | juho.pirskanen@nokia.com | Rel-7 | TSG | MCC_RAN |
| 35 | 8.3 | UE Performance Requirements for MBMS (TDD) | 328d? | 2005-03-15 A | 2006-06-15 A | 100% | 2005-03-15 | 2006-06-15 | 328d? | finish no earlier than 2006-06-15 | R4 | 2624h | 2624h | MBMS-RAN-RF-TDD | Shin Horng Wong | shwong@ipwireless.com | Rel-7 | TSG | MCC_RAN |
| 36 | 8.4 | Continuous connectivity for packet data users | 524d? | 2005-03-14 A | 2007-03-15 A | 100% | 2005-03-14 | 2007-03-15 | 524d? | finish no earlier than 2007-03-15 | R1 | 4192h | 4192h | RANimp-CPC | Joern Krause | Joern.Krause@siemens.com | Rel-7 | TSG | MCC_RAN |
| 37 | 8.5 | Extended WCDMA Cell Range | 198d? | 2006-03-15 A | 2006-12-15 A | 100% | 2006-03-15 | 2006-12-15 | 198d? | finish no earlier than 2006-12-15 | R3 | 1584h | 1584h | RANimp-ExtCell | Ericsson |  | Rel-7 |  | MCC_RAN |
| 38 | 8.6 | 7.68 Mcps TDD Enhanced Uplink | 198d? | 2006-03-15 A | 2006-12-15 A | 100% | 2006-03-15 | 2006-12-15 | 198d? | finish no earlier than 2006-12-15 | R1 | 1584h | 1584h | RANimp-VHCRTDD-EDCH | Nicholas Anderson | nanderson@ipwireless.com | Rel-7 |  | MCC_RAN |
| 39 | 8.7 | closed - Enhanced CELL_FACH State in FDD | 181d? | 2006-09-25 A | 2007-06-04 A | 100% | 2006-09-25 | 2007-06-04 | 181d? | finish no earlier than 2007-06-04 | R2 | 1448h | 1448h | RANimp-EnhState | Juho Pirskanen, Nokia | juho.pirskanen@nokia.com | Rel-7 |  | MCC_RAN |
| 40 | 8.8 | closed - 64QAM for HSDPA (FDD) | 110d? | 2006-12-15 A | 2007-06-04 A | 100% | 2006-12-15 | 2007-06-04 | 110d? | finish no earlier than 2007-06-04 | R1 | 880h | 880h | RANimp-64QamDownlink | Johan Bergman | Johan.Bergman@ericsson.com | Rel-7 |  | MCC_RAN |
| 41 | 8.9 | Improved L2 support for high data rates | 122d? | 2006-12-15 A | 2007-06-04 A | 100% | 2006-12-15 | 2007-06-04 | 122d? | finish no earlier than 2007-06-04 | R2 | 976h | 976h | RANimp-L2DataRates | Janne Peisa | Janne.Peisa@ericsson.com | Rel-7 |  | MCC_RAN |
| 42 | 8.10 | closed - Introduction of 16QAM in HSUPA (FDD) | 110d? | 2006-12-15 A | 2007-06-04 A | 100% | 2006-12-15 | 2007-06-04 | 110d? | finish no earlier than 2007-06-04 | R1 | 880h | 880h | RANimp-16QamUplink | Karri Ranta-aho | karri.ranta-aho@nokia.com | Rel-7 |  | MCC_RAN |
| 43 | 8.11 | Interface to control Tower Mounted Amplifiers (TMAs) | 196d? | 2006-06-15 A | 2007-03-15 A | 100% | 2006-06-15 | 2007-03-15 | 196d? | finish no earlier than 2007-03-15 | R3 | 1568h | 1568h | RANImp-TMA | Alexej Kulakov, Vodafone |  | Rel-7 |  | MCC_RAN |
| 44 | 8.12 | OAM aspects to Interface to control TMAs | 101d? | 2007-01-26 A | 2007-06-15 A | 100% | 2007-01-26 | 2007-06-15 | 101d? | finish no earlier than 2007-06-15 | S5 | 808h | 808h | RANImp-TMA-OAM | Adrian Neal, Vodafone |  | Rel-7 |  | Adrian |
| 45 | 9 | **3.84 Mcps TDD Enhanced Uplink** | 394d? | 2005-03-15 A | 2006-09-15 A | 100% | 2005-03-15 | 2006-09-15 | 394d? |  | RP | 18384h | 18384h | EDCHTDD | Nicholas Anderson | nanderson@ipwireless.com | Rel-7 | TSG | MCC_RAN |
| 46 | 9.1 | EDCHTDD: Stage 2 | 328d? | 2005-03-15 A | 2006-06-15 A | 100% | 2005-03-15 | 2006-06-15 | 328d? | finish no earlier than 2006-06-15 | R2 | 2624h | 2624h | EDCHTDD-Stage2 | Nicholas Anderson | nanderson@ipwireless.com | Rel-7 | TSG | MCC_RAN |
| 47 | 9.2 | EDCHTDD: Physical Layer | 394d? | 2005-03-15 A | 2006-09-15 A | 100% | 2005-03-15 | 2006-09-15 | 394d? | finish no earlier than 2006-09-15 | R1 | 3152h | 3152h | EDCHTDD-Phys | Nicholas Anderson | nanderson@ipwireless.com | Rel-7 | TSG | MCC_RAN |
| 48 | 9.3 | EDCHTDD: Layer 2 and 3 Protocol Aspects | 394d? | 2005-03-15 A | 2006-09-15 A | 100% | 2005-03-15 | 2006-09-15 | 394d? | finish no earlier than 2006-09-15 | R2 | 3152h | 3152h | EDCHTDD-L23 | Derek Richards | drichards@ipwireless.com | Rel-7 | TSG | MCC_RAN |
| 49 | 9.4 | EDCHTDD: UTRAN Iub/Iur Protocol Aspects | 394d? | 2005-03-15 A | 2006-09-15 A | 100% | 2005-03-15 | 2006-09-15 | 394d? | finish no earlier than 2006-09-15 | R3 | 3152h | 3152h | EDCHTDD-IurIub | Jim Miller | jim.miller@interdigital.com | Rel-7 | TSG | MCC_RAN |
| 50 | 9.5 | EDCHTDD: RF Radio Transmission/ Reception, System Performance Requirements and Conformance Testing | 394d? | 2005-03-15 A | 2006-09-15 A | 100% | 2005-03-15 | 2006-09-15 | 394d? | finish no earlier than 2006-09-15 | R4 | 3152h | 3152h | EDCHTDD-RF | Shin Horng Wong | shwong@ipwireless.com | Rel-7 | TSG | MCC_RAN |

Notes:
- 26: Approved at RP#25 as RP-040365
- 27: Feature completed and closed at RP#33 with the presentation of the test WI / Text3: TS25.202
- 28: Feature completed and closed at RP#33 with the presentation of the test WI / Text3: TS25.221, TS25.222, TS25.223, TS25.224,TS25.225
- 29: Feature completed and closed at RP#33 with the presentation of the test WI / Text3: TS25.301, TS25.302, TS25.305, TS25.306, TS25.321, TS25.331
- 30: Feature completed and closed at RP#33 with the presentation of the test WI / Text3: TS25.401, TS25.420, TS25.423, TS25.425, TS25.427, TS25.430, TS25.433, TS25.435
- 31: Feature completed and closed at RP#33 with the presentation of the test WI / Text3: TS25.102, TS25.105, TS25.123, TS25.133, TS25.142
- 32: Generic feature
- 33: Approved at RP#34 as RP-060682
- 34: Approved at RP#33 as RP-060453 / Text3: TS25.321, TS25.322, TS25.331
- 35: WI completed and closed with the presentation of the test WI / Text3: TS25.102, TS25.123
- 37: Approved at RP#34 as RP-060685 / Text3: 25.133, 25.423, 25.425, 25.433, 25.435, 25.453, 25.331
- 38: Approved at RP#34 as RP-060684 / Text3: 25.201, 25.202, 25.221, 25.222, 25.223, 25.224, 25.225, 25.331, 23.321, 25.306, 25.302, 25.401, 25.420, 25.423, 25.427, 25.433, 25.102, 25.105, 25.142
- 39: WI Acronym corrected, closed but 90% / Text3: 25.308, 25.304, 25.306, 25.321, 25.331, 25.433, 25.435, 25.423, 25.425,
- 40: closed but 99% / Text3: 25.308, 25.211, 25.212, 25.213, 25.306, 25.331, 25.433, 25.435, 25.423, 25.425, 25.101, 25.104, 25.141
- 41: Text3: 25.301, 25.306, 25.321, 25.322, 25.331, 25.433, 25.435, 25.423, 25.425
- 42: closed but 81% / Text3: 25.319, 25.101, 25.104, 25.133, 25.141, 25.211, 25.212, 25.213, 25.214, 25.306, 25.321, 25.331, 25.423, 25.433
- 44: AZ record created / Text3: CRs 32.642/3/5 – Align with RAN 25.466
- 45: Approved at RP#33 as RP-060462
- 47: Text3: TS25.201, TS25.221,TS25.222, TS25.223, TS25.224, TS25.225
- 48: Text3: TS25.301, TS25.302, TS25.306, TS25.321, TS25.331
- 49: Text3: TS25.401, TS25.420, TS25.423, TS25.427, TS25.430, TS25.433, TS25.435
- 50: Text3: TS25.102, TS25.105, TS25.123, TS25.142

| ID | WBS | Task | Type | Duration | Start | Finish | Complete | Baseline start | Baseline finish | Baseline duration | Constraint | Resources | Work | Actual work | Text1 | Text4 | Text6 | Text8 | Text7 | Text2 | Text9 | Text5 | Text12 |
| --- | --- | --- | --- | --- | --- | --- | --- | --- | --- | --- | --- | --- | --- | --- | --- | --- | --- | --- | --- | --- | --- | --- | --- |
| 51 | 10 | **1.28 Mcps TDD Enhanced Uplink** |  | 328d? | 2006-03-15 A | 2007-06-15 A | 100% | 2006-03-15 | 2007-06-15 | 328d? |  | RP | 11536h | 11536h | LCRTDD-EDCH | Haijing Hu (CATT) | Rel-7 | MCC_RAN |  |  |  |  |  |
| 52 | 10.1 | 1.28 Mcps TDD Enhanced Uplink: Physical Layer |  | 262d? | 2006-03-15 A | 2007-03-15 A | 100% | 2006-03-15 | 2007-03-15 | 262d? | finish no earlier than 2007-03-15 | R1 | 2096h | 2096h | LCRTDD-EDCH-Phys | Ke Wang (CATT) | Rel-7 | MCC_RAN |  |  |  |  |  |
| 53 | 10.2 | 1.28 Mcps TDD Enhanced Uplink: Layer 2 and 3 Protocol Aspects |  | 262d? | 2006-03-15 A | 2007-03-15 A | 100% | 2006-03-15 | 2007-03-15 | 262d? | finish no earlier than 2007-03-15 | R2 | 2096h | 2096h | LCRTDD-EDCH-L23 | Haiyang Quan (CATT) | Rel-7 | MCC_RAN |  |  |  |  |  |
| 54 | 10.3 | 1.28 Mcps TDD Enhanced Uplink: UTRAN Iub/Iur Protocol Aspects |  | 262d? | 2006-03-15 A | 2007-03-15 A | 100% | 2006-03-15 | 2007-03-15 | 262d? | finish no earlier than 2007-03-15 | R3 | 2096h | 2096h | LCRTDD-EDCH-IubIur | Yincheng Zhang (CATT) | Rel-7 | MCC_RAN |  |  |  |  |  |
| 55 | 10.4 | 1.28 Mcps TDD Enhanced Uplink: RF Radio Transmission/ Reception, System Performance Requirements and Conformance Testing |  | 328d? | 2006-03-15 A | 2007-06-15 A | 100% | 2006-03-15 | 2007-06-15 | 328d? | finish no earlier than 2007-06-15 | R4 | 2624h | 2624h | LCRTDD-EDCH-RF | Yuexia Song (CATT) | Rel-7 | MCC_RAN |  |  |  |  |  |
| 56 | 11 | **PS domain and IMS impacts for supporting IMS Emergency calls** |  | 1760d? | 2000-09-18 A | 2007-06-15 A | 100% | 2000-09-18 | 2007-06-29 | 1770d? |  | S2 | 44157h | 44157h | EMC1 | Rainer Liebhart | Rel-7 | Maurice | TSG |  |  |  |  |
| 57 | 10.1.1 | Service Requirements for IP-based emergency calls |  | 985d | 2000-09-18 A | 2004-06-25 A | 100% | 2000-09-18 | 2004-06-25 | 985d | finish no earlier than 2004-06-25 | S1 | 7880h | 7880h | EMC1 |  | Rel-7 |  |  | CCaR | 1314 |  |  |
| 58 | 11.2 | Study on Stage 2 for IMS-level solution |  | 668d? | 2003-02-26 A | 2005-09-16 A | 100% | 2003-02-26 | 2005-09-16 | 668d? | finish no earlier than 2005-09-16 | S2 | 5344h | 5344h | EMC1 | Rainer Liebhart, Siemenws | Rel-7 |  | TSG |  |  |  |  |
| 59 | 11.3 | Study on Stage 2 for GPRS-level solution |  | 301d? | 2004-10-14 A | 2005-12-08 A | 100% | 2004-10-14 | 2005-12-08 | 301d? | finish no earlier than 2005-12-08 | S2 | 2408h | 2408h | EMC1 |  | Rel-7 |  |  |  |  |  |  |
| 60 | 11.4 | Stage 2 Specification Phase - IMS-level |  | 200d? | 2005-09-05 A | 2006-06-09 A | 100% | 2005-09-05 | 2006-06-09 | 200d? | finish no earlier than 2006-06-09 | S2 | 1600h | 1600h | EMC1 |  | Rel-7 |  |  |  |  |  |  |
| 61 | 11.5 | Deleted - Stage 2 Specification Phase - GPRS-level | milestone | 0d? | 2007-03-02 A | 2007-03-02 A | 100% | 2005-09-05 | 2007-06-29 | 475d? | start no earlier than 2007-03-02 | S2 |  |  | EMC1 |  | Rel-7 |  |  |  |  |  |  |
| 62 | 10.1 | **Emergency Call Enhancements for IP& PS Based Calls – stage 3** |  | 375d | 2006-01-09 A | 2007-06-15 A | 100% | 2006-01-09 | 2007-06-15 | 375d |  | C1 | 12845h | 12845h | EMC1 | Alf Heidermark (Ericsson) | Rel-7 |  |  | CCaR | 1653 | alf.heidermark@ericsson.com |  |
| 63 | 10.1.2 | CT1 IMS aspects to support IMS Emergency sessions |  | 350.82d | 2006-01-09 A | 2007-06-15 A | 100% | 2006-01-09 | 2007-06-15 | 350.82d | finish no earlier than 2007-06-15 | C1 | 2806.56h | 2806.56h | EMC1 | Alf Heidermark (Ericsson) | Rel-7 |  |  | CCaR | 1315 | alf.heidermark@ericsson.com |  |
| 64 | 10.1.2 | Deleted - CT3 IMS aspects to support IMS Emergency sessions |  | 95d | 2006-05-08 A | 2006-09-15 A | 100% | 2006-05-08 | 2006-09-15 | 95d | finish no earlier than 2006-09-15 | C3 | 760h | 760h | EMC1 | Alf Heidermark (Ericsson) | Rel-7 | Seung Don |  | CCaR | 1315 | alf.heidermark@ericsson.com | CP-TBC |
| 65 | 10.1.5 | Deleted - CT3 PS domain aspects to support IMS Emergency sessions |  | 95d | 2006-05-08 A | 2006-09-15 A | 100% | 2006-05-08 | 2006-09-15 | 95d | start no earlier than 2006-05-08 | C3 | 760h | 760h | EMC1 | Alf Heidermark (Ericsson) | Rel-7 | Seung Don |  | CCaR | 1646 | alf.heidermark@ericsson.com | CP-TBC |
| 66 | 10.1.5 | CT1 PS domain aspects to support IMS Emergency sessions |  | 349.9d | 2006-01-09 A | 2007-06-15 A | 100% | 2006-01-09 | 2007-06-15 | 349.9d | finish no earlier than 2007-06-15 | C1 | 2799.2h | 2799.2h | EMC1 | Alf Heidermark (Ericsson) | Rel-7 |  |  | CCaR | 1646 | alf.heidermark@ericsson.com |  |
| 67 | 10.1.5 | CT4 PS domain aspects to support IMS Emergency sessions |  | 365d | 2006-01-09 A | 2007-06-01 A | 100% | 2006-01-09 | 2007-06-01 | 365d | finish no earlier than 2007-06-01 | C4 | 2920h | 2920h | EMC1-GPRSc4 | Alf Heidermark (Ericsson) | Rel-7 |  |  | CCaR | 1646 | alf.heidermark@ericsson.com |  |
| 68 | 12 | **Access Class Barring and Overload Protection** |  | 650d? | 2004-03-15 A | 2006-09-08 A | 100% | 2004-03-15 | 2006-09-08 | 650d? |  | S2 | 8768h | 8768h | ACBOP | Chris Pudney, Vodafone | Rel-7 | Maurice | TSG |  |  |  |  |
| 69 | 12.1 | TR on Stage 2 |  | 274d? | 2004-03-15 A | 2005-03-31 A | 100% | 2004-03-15 | 2005-03-31 | 274d? | finish no earlier than 2005-03-31 | S2 | 2192h | 2192h | ACBOP |  | Rel-7 |  | TSG |  |  |  |  |
| 70 | 12.2 | Stage 3 CN aspects of ACBOP |  | 172d? | 2005-06-06 A | 2006-01-31 A | 100% | 2005-06-06 | 2006-01-31 | 172d? | start no earlier than 2005-06-06 | C1 | 1376h | 1376h | ACBOP |  | Rel-7 |  |  |  |  |  |  |
| 71 | 12.3 | Deleted - Potential impact on Iu interface Overload functionality | milestone | 0d? | 2004-03-15 A | 2004-03-15 A | 100% | 2004-03-15 | 2004-03-15 | 0d? | finish no earlier than 2004-03-15 | RP |  |  | ACBOP |  | Rel-7 |  |  |  |  |  | RP-25 |
| 72 | 12.4 | Deleted - Extra ACBOP information in RAN | milestone | 0d? | 2004-03-15 A | 2004-03-15 A | 100% | 2004-03-15 | 2004-03-15 | 0d? | finish no earlier than 2004-03-15 | RP |  |  | ACBOP |  | Rel-7 |  |  |  |  |  | RP-25 |
| 73 | 12.5 | Deleted - Extra ACBOP information in GERAN | milestone | 0d? | 2006-09-08 A | 2006-09-08 A | 100% | 2006-09-08 | 2006-09-08 | 0d? | start no earlier than 2006-09-08 | GP |  |  | ACBOP |  | Rel-7 | Gert | TSG |  |  |  | RP-33 |
| 74 | 13 | **USSD message delivery and transfer to USIM** |  | 376d? | 2004-03-05 A | 2005-08-12 A | 100% | 2004-03-05 | 2005-08-12 | 376d? |  | S1 | 5698.4h | 5698.4h | USSD-USIM |  | Rel-7 | Michael | TSG |  |  |  |  |
| 75 | 13.1 | Stage 1 |  | 152d? | 2004-03-18 A | 2004-10-15 A | 100% | 2004-03-18 | 2004-10-15 | 152d? | start no earlier than 2004-03-18 | S1 | 1216h | 1216h | USSD-USIM |  | Rel-7 | Michael | TSG |  |  |  |  |
| 76 | 13.2 | Alignment with requirements regarding USSD usage |  | 193.3d? | 2004-03-05 A | 2005-08-12 A | 100% | 2004-03-05 | 2005-08-12 | 193.3d? | finish no earlier than 2005-08-12 | C6 | 1546.4h | 1546.4h | USSD-USIM | Christophe Dubois (Axalto) | Rel-7 |  | TSG |  |  | cdubois@axalto.com |  |

Notes:
- 52: Text3: 25.201, 25.221, 25.222, 25.223, 25.224, 25.225
- 53: Text3: 25.301, 25.302, 25.306, 25.321, 25.331
- 54: Text3: 25.401, 25.420, 25.423, 25.425, 25.427, 25.430, 25.433, 25.435
- 55: Text3: 25.102, 25.105, 25.123, 25.142
- 57: Text3: 22.976
- 58: Text3: 23.228, 23.060, 23.002
- 63: Text3: 24.229
- 64: CT3 VC: Emergency WIs cancelled for Rel-7 and there is now corresponding Rel-8 work. / Text3: 29.163
- 65: CT3 VC: Emergency WIs cancelled for Rel-7 and there is now corresponding Rel-8 work. / Text3: 29.061
- 66: end date updated by CT1-chairman after CT#33 / Text3: 24.008, 24.234
- 67: CRs Approved in WLAN 40 % done after CT4#33 / Text3: 29.060
- 68: Text3: 23.898
- 70: NEW - inserted on 2/9/2004 / Text3: 24.008
- 71: Text3: 25.413
- 72: Text3: 25.331
- 73: Text3: 44.018
- 74: Text3: 22.090
- 75: Text3: 22.090

| ID | WBS | Task | Type | Duration | Start | Finish | Complete | Baseline start | Baseline finish | Baseline duration | Constraint | Resources | Work | Actual work | Text1 | Text6 | Text8 | Text5 | Text7 | Text12 |
| --- | --- | --- | --- | --- | --- | --- | --- | --- | --- | --- | --- | --- | --- | --- | --- | --- | --- | --- | --- | --- |
| 77 | 14 | **Location Services enhancements Rel-7** |  | 906d? | 2004-06-28 A | 2007-12-17 A | 100% | 2004-06-28 | 2007-06-04 | 766d? |  | S2 | 46933.6h | 46933.6h | LCS3 | Rel-7 | Maurice |  |  |  |
| 78 | 14.1 | Global Stage 2 for LCS3 (including IMS emergency location aspects) |  | 446d? | 2004-12-31 A | 2006-09-15 A | 100% | 2004-12-31 | 2006-09-15 | 446d? | finish no earlier than 2006-09-15 | S2 | 3568h | 3568h | LCS3 | Rel-7 | Maurice | brodilitz@sirf.com | TSG |  |
| 79 | 14.2 | CT4 aspects for LCS |  | 240d? | 2006-01-02 A | 2006-12-01 A | 100% | 2006-01-02 | 2006-12-01 | 240d? | finish no earlier than 2006-12-01 | C4 | 1920h | 1920h | LCS3-UEPos-LBS | Rel-7 |  |  | TSG |  |
| 80 | 14.3 | **LCS for 3GPP Interworking WLAN** |  | 700d? | 2004-06-28 A | 2007-03-02 A | 100% | 2004-06-28 | 2007-03-02 | 700d? |  | S1 | 11901.6h | 11901.6h | LCS3-IWLAN | Rel-7 | Michael |  | TSG |  |
| 81 | 14.3.1 | FS on 3GPP system to WLAN Interworking with LCS |  | 512.7d? | 2004-06-28 A | 2006-06-30 A | 100% | 2004-06-28 | 2006-06-30 | 512.7d? | finish no earlier than 2005-09-29 | S1 | 4101.6h | 4101.6h | LCS3-IWLAN | Rel-7 |  |  |  |  |
| 82 | 14.3.2 | Study of work on an LCS architecture for I-WLAN. |  | 180d? | 2006-06-26 A | 2007-03-02 A | 100% | 2006-06-26 | 2007-03-02 | 180d? | finish no earlier than 2007-03-02 | S2 | 1440h | 1440h | LCS3-IWLAN | Rel-7 | Maurice | dhshim@lge.com ; phede@lge.com |  |  |
| 83 | 14.3.3 | Stage 2 CRs for LCS architecture for I-WLAN. |  | 95d? | 2006-10-23 A | 2007-03-02 A | 100% | 2006-10-23 | 2007-03-02 | 95d? | finish no earlier than 2007-03-02 | S2 | 760h | 760h | LCS3-IWLAN | Rel-7 | Maurice |  |  |  |
| 84 | 14.4 | **UE positioning Rel-7** |  | 849d? | 2004-09-15 A | 2007-12-17 A | 100% | 2004-09-15 | 2007-06-04 | 709d? |  | RP | 13584h | 13584h | LCS3-UEpos | Rel-7 | Claude |  | TSG |  |
| 85 | 14.4.1 | Inclusion of Uplink TDOA UE positioning method in the UTRAN specifications |  | 849d? | 2004-09-15 A | 2007-12-17 A | 100% | 2004-09-15 | 2007-06-04 | 709d? | finish no earlier than 2007-12-17 | R2 | 6792h | 6792h | LCS3-UEPos-UTDOA | Rel-7 | MCC_RAN | rlgross@trueposition.com | TSG |  |
| 86 | 14.5 | UE positioning - Velocity |  | 394d? | 2005-03-15 A | 2006-09-15 A | 100% | 2005-03-15 | 2006-09-15 | 394d? | finish no earlier than 2006-09-15 | R2 | 3152h | 3152h | LCS3-UEPos-Velocity | Rel-7 | MCC_RAN | BRodilitz@SiRF.com | TSG |  |
| 87 | 14.6 | LCS Enhancements Related to Location-Based Services |  | 695d? | 2005-01-03 A | 2007-08-31 A | 100% | 2005-01-03 | 2007-05-18 | 620d? | finish no earlier than 2007-08-31 | GP | 5560h | 5560h | LCS3-LBS | Rel-7 | Paolo | kjudge@sirf.com | TSG |  |
| 88 | 14.7 | Deleted - RAN2 aspects for LBS | milestone | 0d? | 2005-06-15 A | 2005-06-15 A | 100% | 2005-06-15 | 2005-06-15 | 0d? | start no earlier than 2005-06-15 | R2 |  |  | LCS3-UEPos-LBS | Rel-7 | MCC_RAN | BRodilitz@SiRF.com | TSG | RP-31 |
| 89 | 15 | A-GPS Minimum Performance |  | 351d? | 2006-04-28 A | 2007-08-31 A | 100% | 2006-04-28 | 2007-05-18 | 276d? | finish no earlier than 2007-08-31 | G1, G3 | 2808h | 2808h | GAGR | Rel-7 | Paolo | richard.catmur@spirentcom.com |  |  |
| 90 | 16 | **Advanced Global Navigation Satellite System (A-GNSS) concept** |  | 830d? | 2004-06-28 A | 2007-08-31 A | 100% | 2004-06-28 | 2007-06-04 | 766d? |  | S1 | 16193.6h | 16193.6h | LCS3-AGNSS | Rel-7 | Michael | Michel.monnerat@space.alcatel.fr | TSG |  |
| 91 | 16.1 | Deleted - Towards A-GNSS Concept | milestone | 0d? | 2007-02-16 A | 2007-02-16 A | 100% | 2007-02-16 | 2007-02-16 | 0d? | start no earlier than 2007-02-16 | S1 |  |  | GNSS | Rel-7 | Paolo | richard.couty@space.alcatel.fr | TSG | SP-34 |
| 92 | 16.2 | Towards A-GNSS Concept |  | 811.2d? | 2004-06-28 A | 2007-08-31 A | 100% | 2004-06-28 | 2007-05-18 | 736.2d? | finish no earlier than 2007-08-31 | GP | 6489.6h | 6489.6h | AGNSS-GP | Rel-7 | Paolo | richard.couty@space.alcatel.fr | TSG |  |
| 93 | 16.3 | closed - Global Navigation Satellite System (GNSS) in UTRAN |  | 383d? | 2005-12-15 A | 2007-06-04 A | 100% | 2005-12-15 | 2007-06-04 | 383d? | finish no earlier than 2007-06-04 | R2 | 3064h | 3064h | LCS3-GNSS-UTRAN | Rel-7 | MCC_RAN | alain.abinakhoul@francetelecom.com |  |  |
| 94 | 17 | **Combinational Services** |  | 296d? | 2005-01-17 A | 2006-03-06 A | 100% | 2005-01-17 | 2006-03-06 | 296d? |  | S1 | 7544h | 7544h | CSICS | Rel-7 | Michael | Robert.Frank@teliasonera.com | TSG |  |
| 95 | 17.1 | Stage 1 for CSICS |  | 104d? | 2005-01-17 A | 2005-06-09 A | 100% | 2005-01-17 | 2005-06-09 | 104d? | start no earlier than 2005-01-17 | S1 | 832h | 832h | CSICS | Rel-7 |  |  | TSG |  |
| 96 | 17.2 | Stage 2 for CSICS |  | 130d? | 2005-01-17 A | 2005-07-15 A | 100% | 2005-01-17 | 2005-07-15 | 130d? | start no earlier than 2005-01-17 | S2 | 1040h | 1040h | CSICS | Rel-7 |  |  |  |  |
| 97 | 17.3 | Stage 3 for CSICS CN aspects |  | 221d? | 2005-05-02 A | 2006-03-06 A | 100% | 2005-05-02 | 2006-03-06 | 221d? | finish no earlier than 2006-03-06 | C1 | 1768h | 1768h | CSICS | Rel-7 | Andrijana |  | TSG |  |
| 98 | 17.4 | Stage 3 for codec aspects |  | 192d? | 2005-03-15 A | 2005-12-07 A | 100% | 2005-03-15 | 2005-12-07 | 192d? | finish no earlier than 2005-12-07 | S4 | 1536h | 1536h | CSICS-Codec | Rel-7 | Paolo | Per.Frojdh@ericsson.com | TSG |  |
| 99 | 18 | **System enhancements for fixed broadband access to IMS** |  | 876d? | 2003-11-05 A | 2007-03-15 A | 100% | 2003-11-05 | 2007-03-15 | 876d? |  | S2 | 42721.6h | 42721.6h | FBI | Rel-7 | Maurice |  | TSG |  |
| 100 | 18.1 | **TISPAN Rel 1 related aspects** |  | 873d? | 2003-11-05 A | 2007-03-09 A | 100% | 2003-11-05 | 2007-03-09 | 873d? |  | S2 | 31568h | 31568h | FBI-TIS1 | Rel-7 |  |  |  |  |
| 101 | 18.1.1 | Stage 2 of FBI for TISPAN R1 |  | 365d? | 2004-10-14 A | 2006-03-08 A | 100% | 2004-10-14 | 2006-03-08 | 365d? | start no earlier than 2004-10-14 | S2 | 2920h | 2920h | FBI-TIS1 | Rel-7 | Maurice |  |  |  |

Notes:
- 77: Text3: 23.271
- 78: Approved SA#27. Appropriate place forEmergency work to be found / Text3: 23.271 / Text4: Ben Rodilitz, SiRF
- 79: CRs approved in CT4#30...
- 80: Text3: 22.935 / Text4: Mike Loushine, (Telcordia)
- 81: DAB - Should be SA1 / Text3: 22.935
- 82: Updated WID at SA#32 to change "stage 2" to "study" , duplicated UID 320017 deleted. Exception Granted for Rel-7 until 03/07 / Text3: 23.837 / Text4: Donghee Shim (LG Electronics Inc.); Patrice HÉDÉ (LG Electronics Mobilecomm France)
- 83: WID at SA#55
- 85: Text3: TS25.305, TS25.453 / Text4: Robert Gross, TruePosition
- 86: Approved at RP#33 as RP-060459 / Text3: 25.305, 25.331, 25.410, 25.413, 25.453 / Text4: Ben Rodilitz
- 87: Linked to SP-040682 / Text3: 43.059, 44.031, 48.008, 49.031 / Text4: Kevin Judge, SiRF Technologies
- 88: Text3: 25.305, 25.331, 25.410, 25.413, 25.453 / Text4: Ben Rodilitz
- 89: Text3: 45.005, 51.010 / Text4: Richard Catmur, Spirent Communications
- 90: Text4: Michel MONNERAT
- 91: Text4: Richard Couty, ALCATEL SA
- 92: Started / Text4: Richard Couty, ALCATEL SA
- 93: closed but 90% / Text3: TS 25.305,TS 25.331,TS 25.306,TS 25.413,TS 25.423,TS 25.433,TS 25.453,TS 25.171,TS 34.171 / Text4: Alain Abinakhoul, France Telecom
- 94: Text4: Robert Frank, TeliaSonera
- 95: Text3: 22.279
- 96: Text3: 23.279
- 97: Text3: New TS 24.279, 24.229, 24.008 / Text4: Peter Dawes (Vodafone)
- 98: Started / Text3: TS 26.141, 26.235 / Text4: Per Fröjdh, Ericsson

| ID | WBS | Task | Duration | Start | Finish | Complete | Baseline start | Baseline finish | Baseline duration | Constraint | Resources | Work | Actual work | Text1 | Text3 | Text4 | Text6 | Text7 | Text8 | Text5 | Text12 |
| --- | --- | --- | --- | --- | --- | --- | --- | --- | --- | --- | --- | --- | --- | --- | --- | --- | --- | --- | --- | --- | --- |
| 102 | 18.1.2 | **Protocol impact of FBI for TISPAN R1** | 873d? | 2003-11-05 A | 2007-03-09 A | 100% | 2003-11-05 | 2007-03-09 | 873d? |  | C1 | 20720h | 20720h | FBI-TIS1 | new TR 24.819, 24.229, 29.229, 29.163, 29.209 | Peter Leis (Siemens) | Rel-7 | TSG | Andrijana |  |  |
| 103 | 18.1.2.1 | CT1 aspects of FBI for TISPAN R1 | 802d? | 2003-11-05 A | 2006-11-30 A | 100% | 2003-11-05 | 2006-11-30 | 802d? | finish no earlier than 2006-11-30 | C1 | 6416h | 6416h | FBI-TIS1 | new TR 24.819, 24.229, 29.229, 29.163, 29.209 | Siemens | Rel-7 | TSG | Andrijana |  |  |
| 104 | 18.1.2.2 | CT3 aspects of FBI for TISPAN R1 | 808d? | 2003-11-05 A | 2006-12-08 A | 100% | 2003-11-05 | 2006-12-08 | 808d? | finish no earlier than 2006-12-08 | C3 | 6464h | 6464h | FBI-TIS1 | new TR, 29.229, 29.163 | Siemens | Rel-7 | TSG | Andrijana |  |  |
| 105 | 18.1.2.3 | CT4 aspects of FBI for TISPAN R1 | 301d? | 2006-01-13 A | 2007-03-09 A | 100% | 2006-01-13 | 2007-03-09 | 301d? | finish no earlier than 2007-03-09 | C4 | 2408h | 2408h | FBI-TIS1-st3-c4 | 29.209 | Siemens | Rel-7 | TSG | Andrijana |  |  |
| 106 | 18.1.3 | Security Enhancements for FBI | 118d? | 2005-06-28 A | 2005-12-08 A | 100% | 2005-06-28 | 2005-12-08 | 118d? | start no earlier than 2005-06-28 | S3 | 944h | 944h | FBI-ISE | 33.102, 43.020 | Bengt Sahlin, Ericsson | Rel-7 |  | Mike | Bengt.Sahlin@ericsson.com |  |
| 107 | 18.2 | **PacketCable Related aspects** | 291d? | 2006-02-01 A | 2007-03-15 A | 100% | 2006-02-01 | 2007-03-15 | 291d? |  | S2 | 7248h | 7248h | FBI-PCBL |  |  | Rel-7 |  |  |  |  |
| 108 | 18.2.1 | Stage 2 of FBI for PacketCable | 228d? | 2006-02-01 A | 2006-12-15 A | 100% | 2006-02-01 | 2006-12-15 | 228d? | finish no earlier than 2006-12-15 | S2 | 1824h | 1824h | FBI-PCBL |  |  | Rel-7 |  |  |  |  |
| 109 | 18.2.2 | Protocol impact of FBI for PacketCable | 228d? | 2006-05-01 A | 2007-03-15 A | 100% | 2006-05-01 | 2007-03-15 | 228d? | finish no earlier than 2007-03-15 | C1 | 1824h | 1824h | FBI-PCBL |  |  | Rel-7 |  |  |  |  |
| 110 | 18.2.3 | SA5 Charging aspects of FBI for PacketCable | 180d? | 2006-03-31 A | 2006-12-07 A | 100% | 2006-03-31 | 2006-12-07 | 180d? | finish no earlier than 2006-12-07 | S5 | 1440h | 1440h | FBI-PCBL-CH | 32.240, 32.260, 32.298, 32.299 | CableLabs | Rel-7 |  | Adrian | Bernie McKibben |  |
| 111 | 19 | **Mp (MRFC - MRFP) interface** | 345d? | 2006-02-13 A | 2007-06-08 A | 100% | 2006-02-13 | 2007-06-08 | 345d? |  | C4 | 7144h | 7144h | Mp |  | Phil Hodges, Ericsson | Rel-7 |  | Kimmo | philip.hodges@ericsson.com |  |
| 112 | 19.1 | CT1 aspects of Mp | 1d | 2006-02-13 A | 2006-02-13 A | 100% | 2006-02-13 | 2006-02-13 | 1d | finish no earlier than 2006-02-13 | C1 | 8h | 8h | Mp | 24.229 | Ericsson | Rel-7 |  |  |  |  |
| 113 | 19.2 | Deleted - CT3 aspects of Mp | 1d | 2006-09-22 A | 2006-09-22 A | 100% | 2006-09-22 | 2006-09-22 | 1d | start no earlier than 2006-09-22 | C3 | 8h | 8h | Mp | 29.162 | Ericsson | Rel-7 |  |  |  | CP-33 |
| 114 | 19.3 | Procedures description | 201d? | 2006-06-02 A | 2007-03-09 A | 100% | 2006-06-02 | 2007-03-09 | 201d? | finish no earlier than 2007-03-09 | C4 | 1608h | 1608h | Mp-PROCc4 | 23.333 | Chen Cheng, Huawei | Rel-7 |  | Kimmo | h_hua@huawei.com |  |
| 115 | 19.4 | Stage 3 | 345d | 2006-02-13 A | 2007-06-08 A | 100% | 2006-02-13 | 2007-06-08 | 345d | finish no earlier than 2007-06-08 | C4 | 2760h | 2760h | Mp-St3c4 | 29.333 | Phil Hodges, Ericsson | Rel-7 |  | Kimmo | philip.hodges@ericsson.com |  |
| 116 | 20 | IMS Stage 3 IETF Protocol alignment | 589d? | 2004-12-10 A | 2007-03-15 A | 100% | 2004-12-10 | 2007-03-15 | 589d? | finish no earlier than 2007-03-15 | C1 | 4712h | 4712h | IMSProtoc | TR 24.930 |  | Rel-7 |  |  |  |  |
| 117 | 21 | **Support of SMS over generic 3GPP IP access.** | 696d? | 2004-10-14 A | 2007-06-15 A | 100% | 2004-10-14 | 2007-06-15 | 696d? |  | S2 | 22192h | 22192h | SMSIP | TR 23.abc, TS 23.abc | Wenlin Zhang (Huawei) | Rel-7 | TSG | Maurice | zhangwenlin@huawei.com |  |
| 118 | 21.1 | FS on SMSIP | 173d? | 2004-10-14 A | 2005-06-13 A | 100% | 2004-10-14 | 2005-06-13 | 173d? | start no earlier than 2004-10-14 | S2 | 1384h | 1384h | SMSIP | 23.804 |  | Rel-7 |  |  |  |  |
| 119 | 21.2 | Stage 2 for SMSIP | 333d? | 2005-06-08 A | 2006-09-15 A | 100% | 2005-06-08 | 2006-09-15 | 333d? | finish no earlier than 2006-09-15 | S2 | 2664h | 2664h | SMSIP | 23.204 |  | Rel-7 |  |  |  |  |
| 120 | 21.3 | **Stage 3 for SMSIP** | 527d? | 2005-06-08 A | 2007-06-15 A | 100% | 2005-06-08 | 2007-06-15 | 527d? |  | C4 | 12576h | 12576h | SMSIP-St3 |  | Jari Jansson, Nokia | Rel-7 |  |  | jari.jansson@nokia.com |  |
| 121 | 21.3.1 | CT1 aspects for SMSIP | 527d? | 2005-06-08 A | 2007-06-15 A | 100% | 2005-06-08 | 2007-06-15 | 527d? | finish no earlier than 2007-06-15 | C1 | 4216h | 4216h | SMSIP |  |  | Rel-7 |  |  |  |  |
| 122 | 21.3.2 | CT4 aspects for SMSIP | 518d? | 2005-06-08 A | 2007-06-01 A | 100% | 2005-06-08 | 2007-06-01 | 518d? | finish no earlier than 2007-06-01 | C4 | 4144h | 4144h | SMSIP-St3-c4 |  |  | Rel-7 |  |  |  |  |
| 123 | 22 | **Evolution of Policy Control and Charging** | 817d? | 2004-10-14 A | 2007-11-30 A | 100% | 2004-10-14 | 2007-06-15 | 697d? |  | S2 | 30336h | 30336h | PCC |  |  | Rel-7 | TSG | Maurice |  |  |
| 124 | 22.1 | TR for PCC | 315d? | 2004-10-14 A | 2005-12-29 A | 100% | 2004-10-14 | 2005-12-29 | 315d? | finish no earlier than 2005-12-28 | S2 | 2520h | 2520h | PCC |  |  | Rel-7 |  |  |  |  |
| 125 | 22.2 | Stage 2 for PCC | 315d? | 2005-07-04 A | 2006-09-15 A | 100% | 2005-07-04 | 2006-09-15 | 315d? | finish no earlier than 2006-09-15 | S2 | 2520h | 2520h | PCC | 23.203 |  | Rel-7 |  |  |  |  |
| 126 | 22.3 | Evolution of policy control and flow based bearer level charging | 109d? | 2006-08-01 A | 2006-12-29 A | 100% | 2006-08-01 | 2006-12-29 | 109d? | start no earlier than 2006-08-01 | S2 | 872h | 872h | PCC | 23.207, 23.125, 23.002, 23.228 | Balazs Bertenyi (Nokia) | Rel-7 |  |  | balazs.bertenyi@nokia.com |  |
| 127 | 22.4 | SA5 Charging aspects of PCC | 316d? | 2006-03-31 A | 2007-06-15 A | 100% | 2006-03-31 | 2007-06-15 | 316d? | finish no earlier than 2007-06-15 | S5 | 2528h | 2528h | PCC-CH | 32.250, 32.251, 32.298, 32.299 | Orange | Rel-7 |  | Adrian | alain.bibas@orange-ft.com |  |
| 128 | 22.5 | Gx reference point for Policy and Charging Control | 521d? | 2005-12-02 A | 2007-11-30 A | 100% | 2005-12-02 | 2007-05-11 | 376d? | finish no earlier than 2007-09-14 | C3 | 4168h | 4168h | PCC-Gx | 29.210, 29.207, 29.208 | Thomas Belling (Siemens) | Rel-7 |  | Seung Don | thomas.belling@siemens.com |  |

Notes:
- 103: end date updated by CT1-chairman after CT#33
- 105: CT4#32: a set of CRs on FBI for cable labs
- 106: Duplicated entry ("ACCSEC2", "Access Security Enhancements", SP-040865) deleted by A.Sultan
- 110: 03/2006 SA#31 WID approved
- 113: CT3 finally not involved in Mp interface definition (decided at CT#34)
- 115: indication in CT4#31 50%
- 116: TR 24.930: Signalling flows for the session setup in the IM CN subsystem based on Session Initiation Protocol (SIP)
- 117: Revised at SP#29
- 122: CT4#32: Stage 2 CR still outstanding....
- 126: Approved at SP#29. 23.125 will be discontinued from Release 7.
- 127: 03/2006 SA#31 WID approved

| ID | WBS | Task | Type | Duration | Start | Finish | Complete | Baseline start | Baseline finish | Baseline duration | Constraint | Resources | Work | Actual work | Text1 | Text4 | Text5 | Text6 | Text8 | Text7 |
| --- | --- | --- | --- | --- | --- | --- | --- | --- | --- | --- | --- | --- | --- | --- | --- | --- | --- | --- | --- | --- |
| 129 | 22.6 | **Rx reference point for PCC CT3 aspects** |  | 521d? | 2005-12-02 A | 2007-11-30 A | 100% | 2005-12-02 | 2007-06-15 | 401d? |  | C3 | 11192h | 11192h | PCC-Rx | Javier Pastor (Ericsson) | j.javier.pastor@ericsson.com | Rel-7 | Seung Don |  |
| 130 | 22.6.1 | PCC-Rx CT3 aspects |  | 521d? | 2005-12-02 A | 2007-11-30 A | 100% | 2005-12-02 | 2007-05-11 | 376d? | finish no earlier than 2007-09-14 | C3 | 4168h | 4168h | PCC-Rx-c3 | Javier Pastor (Ericsson) | j.javier.pastor@ericsson.com | Rel-7 | Seung Don |  |
| 131 | 22.6.2 | PCC-Rx CT1 aspects |  | 357d? | 2005-12-02 A | 2007-06-15 A | 100% | 2005-12-02 | 2007-06-15 | 357d? | finish no earlier than 2007-06-15 | C1 | 2856h | 2856h | PCC-Rx-Gx-c1 |  |  | Rel-7 |  |  |
| 132 | 23 | Video Codec Performance Requirements |  | 634d? | 2005-01-03 A | 2007-06-07 A | 100% | 2005-01-03 | 2007-06-07 | 634d? | finish no earlier than 2007-06-07 | S4 | 5072h | 5072h | VICPer | Juergen Pandel (Siemens AG) | juergen.pandel@siemens.com | Rel-7 | Paolo | TSG |
| 133 | 24 | DIAMETER on the GGSN Gi interface |  | 586d? | 2004-09-10 A | 2006-12-08 A | 100% | 2004-09-10 | 2006-12-08 | 586d? | finish no earlier than 2006-12-08 | C3 | 4688h | 4688h | DIAMGi | Nico Gabriele (Vodafone) | Nico.Gabriele@vodafone.com | Rel-7 | Seung Don | TSG |
| 134 | 25 | DIAMETER on the PDG Wi inteface |  | 586d? | 2004-09-10 A | 2006-12-08 A | 100% | 2004-09-10 | 2006-12-08 | 586d? | finish no earlier than 2006-12-08 | C3 | 4688h | 4688h | DIAMWi | Nico Gabriele (Vodafone) | Nico.Gabriele@vodafone.com | Rel-7 | Seung Don | TSG |
| 135 | 26 | **CAMEL Trunk Triggers** |  | 251d? | 2004-12-17 A | 2005-12-05 A | 100% | 2004-12-17 | 2005-12-05 | 251d? |  | S1 | 6024h | 6024h | TTCAMEL | Amar Deol, Nortel Networks | deola@nortelnetworks.com | Rel-7 | Michael | TSG |
| 136 | 26.1 | Stage 1 for CAMEL Trunk Triggers |  | 251d? | 2004-12-17 A | 2005-12-05 A | 100% | 2004-12-17 | 2005-12-05 | 251d? |  | S1 | 2008h | 2008h | TTCAMEL | Amar Deol, Nortel Networks | deola@nortelnetworks.com | Rel-7 | Michael | TSG |
| 137 | 26.2 | CAMEL Trunk Originated Trigger Detection Points |  | 251d? | 2004-12-17 A | 2005-12-05 A | 100% | 2004-12-17 | 2005-12-05 | 251d? | start no earlier than 2004-12-17 | C4 | 2008h | 2008h | CamelR7 | David Hutton, Nortel Networks | dhutton@nortel.com | Rel-7 | Kimmo | TSG |
| 138 | 27 | **Lower 700 MHz Inclusion in the GERAN Specifications** |  | 390d? | 2005-01-03 A | 2006-06-30 A | 100% | 2005-01-03 | 2006-06-30 | 390d? |  | GP | 7632h | 7632h | GSM710 | Dave Cotton (UTC) | dcotton@mtview.union-tel.com | Rel-7 | Paolo | TSG |
| 139 | 27.1 | Inclusion of the 698 – 746 MHz band into GERAN core specifications |  | 129d? | 2005-01-03 A | 2005-06-30 A | 100% | 2005-01-03 | 2005-06-30 | 129d? | finish no earlier than 2005-06-30 | G1 | 1032h | 1032h | GSM710-core |  |  | Rel-7 | Paolo |  |
| 140 | 27.2 | G1 aspects of GSM710 |  | 217.5d? | 2005-08-31 A | 2006-06-30 A | 100% | 2005-08-31 | 2006-06-30 | 217.5d? | finish no earlier than 2006-06-30 | G1 | 1740h | 1740h | GSM-710-test |  |  | Rel-7 | Paolo |  |
| 141 | 27.3 | G3 aspects of GSM710 |  | 217.5d? | 2005-08-31 A | 2006-06-30 A | 100% | 2005-08-31 | 2006-06-30 | 217.5d? | finish no earlier than 2006-06-30 | G3 | 1740h | 1740h | GSM-710-test |  |  | Rel-7 | Stoyan |  |
| 142 | 28 | **Enhancements of VGCS for public authority officials** |  | 731d? | 2004-08-27 A | 2007-06-15 A | 100% | 2004-08-27 | 2007-06-15 | 731d? |  | S1 | 25920h | 25920h | EVGCS | Siemens |  | Rel-7 | Andrijana | TSG |
| 143 | 28.1 | Stage 1 | milestone | 0d? | 2004-08-27 A | 2004-08-27 A | 100% | 2004-08-27 | 2004-08-27 | 0d? | finish no earlier than 2004-08-27 | S1 |  |  | EVGCS | Joerg Swetina (Siemens AG) | joerg.swetina@SIEMENS.COM | Rel-7 | Michael | TSG |
| 144 | 28.2 | **Architecture and protocol aspects** |  | 731d? | 2004-08-27 A | 2007-06-15 A | 100% | 2004-08-27 | 2007-06-15 | 731d? |  | C1 | 14904h | 14904h | EVGCS | Robert Zaus (Siemens) |  | Rel-7 |  |  |
| 145 | 28.2.1 | CT1 aspects of EVGCS |  | 731d? | 2004-08-27 A | 2007-06-15 A | 100% | 2004-08-27 | 2007-06-15 | 731d? | finish no earlier than 2006-09-15 | C1 | 5848h | 5848h | EVGCS | Siemens |  | Rel-7 |  |  |
| 146 | 28.2.2 | CT4 aspects of EVGCS |  | 401d? | 2004-08-27 A | 2006-03-10 A | 100% | 2004-08-27 | 2006-03-10 | 401d? | finish no earlier than 2006-03-10 | C4 | 3208h | 3208h | EVGCS-St23-c4 | Siemens |  | Rel-7 |  |  |
| 147 | 28.3 | GERAN2 aspects |  | 646d? | 2004-08-27 A | 2007-02-16 A | 100% | 2004-08-27 | 2007-02-16 | 646d? | finish no earlier than 2007-02-16 | G2 | 5168h | 5168h | EVGCS | Ken Isaacs (Siemens) | kenneth.isaacs@roke.co.uk | Rel-7 | Gert | TSG |
| 148 | 29 | **Improvements of VGCS for parallel use of services** |  | 523d? | 2005-03-15 A | 2007-03-15 A | 100% | 2005-03-15 | 2007-03-15 | 523d? |  | S1 | 12230.2h | 12230.2h | IVGCS |  |  | Rel-7 |  |  |
| 149 | 29.1 | Service Requirements for VGCS improvements |  | 62d? | 2005-03-15 A | 2005-06-08 A | 100% | 2005-03-15 | 2005-06-08 | 62d? | finish no earlier than 2005-06-08 | S1 | 496h | 496h | IVGCS | Kurt Bischinger (T-Mobile) | kurt.bischinger@t-mobile.at | Rel-7 | Michael | TSG |
| 150 | 29.2 | Stage 2 modifications for VGCS improvements |  | 335d? | 2005-12-01 A | 2007-03-14 A | 100% | 2005-12-01 | 2007-03-14 | 335d? | start no earlier than 2005-12-01 | C1 | 2680h | 2680h | IVGCS | Kurt Bischinger (T-Mobile) | kurt.bischinger@t-mobile.at | Rel-7 |  | TSG |
| 151 | 29.3 | **Protocol aspects** |  | 336d? | 2005-12-01 A | 2007-03-15 A | 100% | 2005-12-01 | 2007-03-15 | 336d? |  | C1 | 5376h | 5376h | IVGCS | Dieter Jacobsohn (T-Mobile) |  | Rel-7 |  |  |
| 152 | 29.3.1 | CT1 aspects of IVGCS |  | 336d? | 2005-12-01 A | 2007-03-15 A | 100% | 2005-12-01 | 2007-03-15 | 336d? | finish no earlier than 2007-03-15 | C1 | 2688h | 2688h | IVGCS | T-Mobile |  | Rel-7 |  |  |
| 153 | 29.3.2 | Deleted - CT4 aspects of IVGCS | milestone | 0d? | 2007-03-09 A | 2007-03-09 A | 100% | 2007-03-09 | 2007-03-09 | 0d? | finish no earlier than 2007-03-09 | C4 |  |  | IVGCS-St3-c4 | T-mobile |  | Rel-7 |  |  |

Notes:
- 129: Approved at CP#30, Revised at CP#31, Revised at CP#33 / Text3: 29.209, 29.211, 24.229
- 130: Text3: 29.209, 29.211, 24.229
- 132: Text3: 26.234, 26.235, 26.346, 26.140, 26.902
- 133: 13/12/2005 08:00, Revised at CP#33 / Text3: 29.061
- 134: 13/12/2005 08:00, Revised at CP#33 / Text3: 29.161
- 136: Text3: 22.078
- 137: Not started
- 138: Text3: 24.008, 43.022, 44.018, 44.118, 45, 001, 45.005, 51.010, 51.021
- 139: Completed / Text3: 24.008, 43.022, 44.018, 44.118, 45, 001, 45.005,
- 140: Text3: 51.021
- 141: Text3: 51.010
- 142: Text3: 43.068, 44.068, 24.008, 29.002
- 143: Text3: 42.068, 43.068
- 144: Text3: 43.068, 44.068
- 145: Text3: 43.068, 44.068, 24.008
- 146: Text3: 29.002
- 149: "completeed" as from Chris S' e-mail / Text3: 42.068
- 150: Updated by CT1 chair / Text3: 43.068
- 151: Previous name (before CT32) was Architecture and protocol aspects / Text3: 44.068
- 152: end date updated by CT1-chairman after CT#33 / Text3: 43.068, 44.068
- 153: CT4#33 stage 2 solution is still open. ... / Text3: 29.002

| ID | WBS | Task | Type | Duration | Start | Finish | Complete | Baseline start | Baseline finish | Baseline duration | Constraint | Resources | Work | Actual work | Text1 | Text4 | Text5 | Text6 | Text7 | Text8 | Text3 | Text10 |
| --- | --- | --- | --- | --- | --- | --- | --- | --- | --- | --- | --- | --- | --- | --- | --- | --- | --- | --- | --- | --- | --- | --- |
| 154 | 30 | **OSA Rel-7** |  | 584d? | 2005-03-15 A | 2007-06-08 A | 100% | 2005-03-15 | 2007-06-09 | 584d? |  | S1 | 17920h | 17920h | OSA7 | Eamonn Murray (AePONA) | eamonn.murray@aepona.com | Rel-7 | TSG | Michael |  |  |
| 155 | 30.1 | Service Requirements for OSA Service Broker |  | 62d? | 2005-03-15 A | 2005-06-08 A | 100% | 2005-03-15 | 2005-06-08 | 62d? | finish no earlier than 2005-06-08 | S1 | 496h | 496h | OSA7-SB | Eamonn Murray (AePONA) | eamonn.murray@aepona.com | Rel-7 | TSG | Michael | 22.127 |  |
| 156 | 30.2 | Stage 2 OSA API Service Brokering |  | 156d? | 2006-04-28 A | 2006-12-01 A | 100% | 2006-04-28 | 2006-12-01 | 156d? |  | C5 | 1248h | 1248h | OSA7-SB | AePONA | damian.oneill@aepona.com | Rel-7 | TSG | Adrian | 23.198 |  |
| 157 | 30.3 | Stage 3 OSA API Service Brokering |  | 156d? | 2006-04-28 A | 2006-12-01 A | 100% | 2006-04-28 | 2006-12-01 | 156d? | finish no earlier than 2006-12-01 | C5 | 1248h | 1248h | OSA7-SB | AePONA | damian.oneill@aepona.com | Rel-7 |  |  | 29.198-16 |  |
| 158 | 30.4 | **OSA Stage 2/3 enhancements** |  | 291d? | 2006-04-28 A | 2007-06-08 A | 100% | 2006-04-28 | 2007-06-09 | 291d? |  | C5 | 10256h | 10256h | OSA7 | AePONA | damian.oneill@aepona.com | Rel-7 |  | Adrian | 29.198/9, 23.198 |  |
| 159 | 30.4.1 | Parlay X Message Broadcast Web Service |  | 156d? | 2006-04-28 A | 2006-12-01 A | 100% | 2006-04-28 | 2006-12-01 | 156d? | finish no earlier than 2006-12-01 | C5 | 1248h | 1248h | OSA7 | ETRI |  | Rel-7 |  |  | 29.199-15, 23.198 |  |
| 160 | 30.4.2 | Parlay X Geocoding Web Service |  | 156d? | 2006-04-28 A | 2006-12-01 A | 100% | 2006-04-28 | 2006-12-01 | 156d? | finish no earlier than 2006-12-01 | C5 | 1248h | 1248h | OSA7 | ETRI |  | Rel-7 |  |  | 29.199-16, 23.198 |  |
| 161 | 30.4.3 | Parlay X Application driven QoS Web Service |  | 226d? | 2006-04-28 A | 2007-03-09 A | 100% | 2006-04-28 | 2007-03-09 | 226d? | finish no earlier than 2007-03-09 | C5 | 1808h | 1808h | OSA7 | BT |  | Rel-7 |  |  | 29.199-17, 23.198 |  |
| 162 | 30.4.4 | Parlay-X Device Capabilities and Configuration |  | 162d? | 2006-10-26 A | 2007-06-08 A | 100% | 2006-10-26 | 2007-06-09 | 162d? | finish no earlier than 2007-06-09 | C5 | 1296h | 1296h | OSA7 | Telenor |  | Rel-7 |  |  | 29.199-18, 23.198 |  |
| 163 | 30.4.5 | Parlay-X Multimedia Streaming Session Management Web Service |  | 97d? | 2006-10-26 A | 2007-03-09 A | 100% | 2006-10-26 | 2007-03-09 | 97d? | start no earlier than 2006-10-26 | C5 | 776h | 776h | OSA7 | Telenor |  | Rel-7 |  |  | 29.199-19, 23.198 |  |
| 164 | 30.4.6 | Parlay-X Multimedia Multicast Control Web Service |  | 97d? | 2006-10-26 A | 2007-03-09 A | 100% | 2006-10-26 | 2007-03-09 | 97d? | start no earlier than 2006-10-26 | C5 | 776h | 776h | OSA7 | ETRI |  | Rel-7 |  |  | 29.199-20, 23.198 |  |
| 165 | 30.4.7 | OSA API Conference Call Control SCF |  | 97d? | 2006-10-26 A | 2007-03-09 A | 100% | 2006-10-26 | 2007-03-09 | 97d? | start no earlier than 2006-10-26 | C5 | 776h | 776h | OSA7 | Ericsson |  | Rel-7 |  |  | 29.198-04-5, 23.198 |  |
| 166 | 31 | Dynamic and Interactive Multimedia Scenes |  | 583d? | 2005-03-15 A | 2007-06-07 A | 100% | 2005-03-15 | 2007-06-07 | 583d? | finish no earlier than 2007-06-07 | S4 | 4664h | 4664h | DIMS | Gaëlle MARTIN-COCHER (Streamezzo) | gaelle.martin-cocher@streamezzo.com | Rel-7 | TSG | Paolo | 26.140, 26.142, 26.234, 26.244, 23.346 |  |
| 167 | 32 | Liberty Alliance and 3GPP Security Interworking |  | 451d? | 2005-03-10 A | 2006-11-30 A | 100% | 2005-03-10 | 2006-11-30 | 451d? | finish no earlier than 2006-11-30 | S3 | 3608h | 3608h | LibSec | Silke Holtmanns, Nokia | Silke.Holtmanns@NOKIA.COM | Rel-7 | TSG | Maurice | 33.980 |  |
| 168 | 33 | **WLAN-UMTS Interworking Phase 2** |  | 371d? | 2004-01-05 A | 2005-06-07 A | 100% | 2004-01-05 | 2005-06-07 | 371d? |  | S1 | 3888h | 3888h | WLAN2 | Fredric Paint, Telenor | frederic.paint@telenor.com | Rel-7 | TSG | Michael |  |  |
| 169 | 33.1 | Stage 1 on Session Continuity |  | 115d? | 2004-01-05 A | 2004-06-11 A | 100% | 2004-01-05 | 2004-06-11 | 115d? | start no earlier than 2004-01-05 | S1 | 920h | 920h | WLAN-SC |  |  | Rel-7 |  |  |  | SP-24 |
| 170 | 33.2 | Stage 2 on Session Continuity: covered by SAE | milestone | 0d? | 2005-06-07 A | 2005-06-07 A | 100% | 2005-06-07 | 2005-06-07 | 0d? | finish no earlier than 2005-06-07 | S2 |  |  | WLAN-SC |  |  | Rel-7 |  |  |  |  |
| 171 | 34 | **WLAN Interworking – Private Network access from WLAN 3GPP IP Access** |  | 252d? | 2005-10-10 A | 2006-09-26 A | 100% | 2005-10-10 | 2006-09-26 | 252d? |  | S2 | 6920h | 6920h | WLANPNA |  |  | Rel-7 |  | Maurice |  |  |
| 172 | 34.1 | WLAN-PNA - Stage 2 |  | 185d? | 2005-10-10 A | 2006-06-23 A | 100% | 2005-10-10 | 2006-06-23 | 185d? | start no earlier than 2005-10-10 | S2 | 1480h | 1480h | WLANPNA-st2 | Toshiyuki Tamura (NEC) | tamurato@aj.jp.nec.com | Rel-7 |  | Maurice | 23.234, 33.234 |  |
| 173 | 34.2 | **WLAN-PNA - Stage 3** |  | 170d? | 2006-02-01 A | 2006-09-26 A | 100% | 2006-02-01 | 2006-09-26 | 170d? |  | C1 | 5440h | 5440h | WLANPNA-st3 | Pierre-Jean Muller (NEC) | pierre-jean.muller@nectech.fr | Rel-7 | TSG | Andrijana |  |  |
| 174 | 34.2.1 | CT1 aspets for WLAN-PNA |  | 170d? | 2006-02-01 A | 2006-09-26 A | 100% | 2006-02-01 | 2006-09-26 | 170d? | start no earlier than 2006-02-01 | C1 | 1360h | 1360h | WLANPNA-st3 | Pierre-Jean Muller (NEC) | pierre-jean.muller@nectech.fr | Rel-7 |  | Andrijana | 24.234 |  |
| 175 | 34.2.2 | CT3 aspets for WLAN-PNA |  | 170d? | 2006-02-01 A | 2006-09-26 A | 100% | 2006-02-01 | 2006-09-26 | 170d? | start no earlier than 2006-02-01 | C3 | 1360h | 1360h | WLANPNA-st3 | Pierre-Jean Muller (NEC) | pierre-jean.muller@nectech.fr | Rel-7 |  | Andrijana | 29.161 |  |
| 176 | 34.2.3 | CT4 aspets for WLAN-PNA |  | 170d? | 2006-02-01 A | 2006-09-26 A | 100% | 2006-02-01 | 2006-09-26 | 170d? | start no earlier than 2006-02-01 | C4 | 1360h | 1360h | WLANPNA-st3 | Pierre-Jean Muller (NEC) | pierre-jean.muller@nectech.fr | Rel-7 |  | Andrijana | 29.234 |  |
| 177 | 35 | **Enhancements to support QoS provisioning over 3GPP/WLAN Interworking** |  | 520d? | 2005-03-14 A | 2007-03-09 A | 100% | 2005-03-14 | 2007-03-09 | 520d? |  | S2 | 8360h | 8360h | WLANQOS | Osok Song, Samsung | osok.song@samsung.com | Rel-7 |  | Maurice | 23.836 |  |
| 178 | 35.1 | TR on support of QoS on WLAN |  | 232d? | 2005-03-14 A | 2006-01-31 A | 100% | 2005-03-14 | 2006-01-31 | 232d? | start no earlier than 2005-03-14 | S2 | 1856h | 1856h | WLANQOS |  |  | Rel-7 |  |  |  |  |
| 179 | 35.2 | Stage 2 on support of QoS over 3GPP/WLAN interworking |  | 108d? | 2006-02-01 A | 2006-06-30 A | 100% | 2006-02-01 | 2006-06-30 | 108d? | start no earlier than 2006-02-01 | S2 | 864h | 864h | WLANQOS |  |  | Rel-7 |  |  |  |  |
| 180 | 35.3 | Stage 3 CT1 on support of QoS over 3GPP/WLAN Interworking |  | 64d? | 2006-09-04 A | 2006-11-30 A | 100% | 2006-09-04 | 2006-11-30 | 64d? | finish no earlier than 2006-11-30 | C1 | 512h | 512h | WLANQOS |  |  | Rel-7 |  |  |  |  |
| 181 | 35.4 | Stage 3 CT4 on support of QoS over 3GPP/WLAN Interworking |  | 121d? | 2006-09-22 A | 2007-03-09 A | 100% | 2006-09-22 | 2007-03-09 | 121d? | finish no earlier than 2007-03-09 | C4 | 968h | 968h | WLAN-QOS | Peng Zhang, Huawei | zhang.peng@huawei.com | Rel-7 |  |  | 24.234, 29.234, 23.008 |  |

Notes:
- 155: az: WID URL corrected
- 158: CT#34: WID updated. Completion 12/06 =>03/07
- 167: WID approved SA#27.
- 168: Created at TSG#27 by A. Sultan because of WLAN items belonging to Rel-7
- 171: Placeholder created to Hold SA2 and CT1 BBs
- 172: Approved at SP#29
- 173: Approved at CP#29
- 174: Approved at CP#29
- 175: Approved at CP#29
- 176: CT4#31; no impacts identified, therefor completed
- 177: Moved from FS section Feb 06
- 180: Line added according to e-mail from Atle
- 181: WID was approved at CT#32...

| ID | WBS | Task | Type | Duration | Start | Finish | Complete | Baseline start | Baseline finish | Baseline duration | Constraint | Resources | Work | Actual work | Text1 | Text4 | Text5 | Text6 | Text8 | Text12 | Text7 |
| --- | --- | --- | --- | --- | --- | --- | --- | --- | --- | --- | --- | --- | --- | --- | --- | --- | --- | --- | --- | --- | --- |
| 182 | 36 | **Voice call continuity between CS and IMS (incl. I-WLAN)** |  | 641d? | 2004-12-31 A | 2007-06-15 A | 100% | 2004-12-31 | 2007-06-15 | 641d? |  | S2 | 20216h | 20216h | VCC | Andy Bennett, Lucent; Roger Bunting, Cingular | andybennett@Alcatel-Lucent.com | Rel-7 | Maurice |  |  |
| 183 | 36.1 | TR for VCC |  | 245d? | 2004-12-31 A | 2005-12-08 A | 100% | 2004-12-31 | 2005-12-08 | 245d? | finish no earlier than 2005-12-08 | S2 | 1960h | 1960h | VCC |  |  | Rel-7 |  |  |  |
| 184 | 36.2 | Stage 1 for VCC |  | 140d? | 2005-03-17 A | 2005-09-28 A | 100% | 2005-03-17 | 2005-09-28 | 140d? | finish no earlier than 2005-09-28 | S1 | 1120h | 1120h | VCC |  |  | Rel-7 | Mike |  |  |
| 185 | 36.3 | Stage 2 for VCC |  | 264d? | 2005-09-06 A | 2006-09-08 A | 100% | 2005-09-06 | 2006-09-08 | 264d? | finish no earlier than 2006-09-08 | S2 | 2112h | 2112h | VCC |  |  | Rel-7 |  |  |  |
| 186 | 36.4 | **Stage 3 for VCC** |  | 358d? | 2006-02-01 A | 2007-06-15 A | 100% | 2006-02-01 | 2007-06-15 | 358d? |  | C1 | 7296h | 7296h | VCC | Keith Drage (Alcatel-Lucent) | drage@alcatel-lucent.com | Rel-7 |  |  |  |
| 187 | 36.4.1 | CT1 aspects of VCC |  | 358d? | 2006-02-01 A | 2007-06-15 A | 100% | 2006-02-01 | 2007-06-15 | 358d? | finish no earlier than 2007-06-15 | C1 | 2864h | 2864h | VCC | Keith Drage (Alcatel-Lucent) | drage@alcatel-lucent.com | Rel-7 | Andrijana |  |  |
| 188 | 36.4.2 | CT4 aspects of VCC |  | 196d? | 2006-06-09 A | 2007-03-09 A | 100% | 2006-06-09 | 2007-03-09 | 196d? | start no earlier than 2006-06-09 | C4 | 1568h | 1568h | VCC-St3-c4 | Keith Drage Alcatel- (Lucent) | drage@alcatel-ucent.com | Rel-7 | Kimmo |  |  |
| 189 | 36.4.3 | Deleted - CT3 aspects of VCC | milestone | 0d? | 2006-11-02 A | 2006-11-02 A | 100% | 2006-11-02 | 2006-11-02 | 0d? | finish no earlier than 2006-11-02 | C3 |  |  | VCC | Keith Drage (Lucent) | drage@lucent.com | Rel-7 |  | CP-33 |  |
| 190 | 36.5 | SA5 Charging aspects of VCC |  | 325d? | 2006-03-17 A | 2007-06-14 A | 100% | 2006-03-17 | 2007-06-14 | 325d? | finish no earlier than 2007-06-14 | S5 | 2600h | 2600h | VCC-CH | Orange | alain.bibas@orange-ft.com | Rel-7 | Adrian |  |  |
| 191 | 37 | **OAM&P** |  | 472.86d? | 2005-09-02 A | 2007-06-26 A | 100% | 2004-02-16 | 2007-06-15 | 870d? |  | S5 | 82725.8h | 82725.8h | OAM7 | Toche | Christian.Toche@huawei.com | Rel-7 | Adrian |  | TSG |
| 192 | 37.1 | **Network Infrastructure Management** |  | 465d? | 2005-09-02 A | 2007-06-14 A | 100% | 2005-09-02 | 2007-06-14 | 465d? |  | S5 | 41800h | 41800h | OAM7-NIM |  |  | Rel-7 |  |  |  |
| 193 | 37.1.1 | Enhance NRM to accommodate NGN (IMS as basis of the Next Generation Network) |  | 465d? | 2005-09-02 A | 2007-06-14 A | 100% | 2005-09-02 | 2007-06-14 | 465d? | finish no earlier than 2007-06-14 | S5 | 3720h | 3720h | OAM7-NIM | Motorola |  | Rel-7 |  |  |  |
| 194 | 37.1.2 | Co-operative Element Management interface (CO-OP) (Study + Implementation) |  | 400d? | 2005-09-02 A | 2007-03-15 A | 100% | 2005-09-02 | 2007-03-15 | 400d? | finish no earlier than 2007-03-15 | S5 | 3200h | 3200h | OAM7-NIM | Motorola |  | Rel-7 |  |  |  |
| 195 | 37.1.3 | Network Management (NM) Itf-N performance criteria |  | 465d? | 2005-09-02 A | 2007-06-14 A | 100% | 2005-09-02 | 2007-06-14 | 465d? | finish no earlier than 2007-06-14 | S5 | 3720h | 3720h | OAM7-NIM | China Mobile |  | Rel-7 |  |  |  |
| 196 | 37.1.4 | Delta synchronization between IRP Manager and IRP Agent (Study + Implementation) |  | 465d? | 2005-09-02 A | 2007-06-14 A | 100% | 2005-09-02 | 2007-06-14 | 465d? | finish no earlier than 2007-06-14 | S5 | 3720h | 3720h | OAM7-NIM | Siemens |  | Rel-7 |  |  |  |
| 197 | 37.1.5 | Subscription Management (SuM) IRP Solution Sets |  | 330d? | 2005-09-02 A | 2006-12-07 A | 100% | 2005-09-02 | 2006-12-07 | 330d? | finish no earlier than 2006-12-07 | S5 | 2640h | 2640h | OAM7-NIM | Ericsson |  | Rel-7 |  |  |  |
| 198 | 37.1.6 | Integration Reference Point (IRP) Security Management |  | 400d? | 2005-09-02 A | 2007-03-15 A | 100% | 2005-09-02 | 2007-03-15 | 400d? | finish no earlier than 2007-03-15 | S5 | 3200h | 3200h | OAM7-NIM | Huawei |  | Rel-7 |  |  |  |
| 199 | 37.1.7 | Partial suspension of Itf-N during maintenance/testing (Study + Implementation) |  | 465d? | 2005-09-02 A | 2007-06-14 A | 100% | 2005-09-02 | 2007-06-14 | 465d? | finish no earlier than 2007-06-14 | S5 | 3720h | 3720h | OAM7-NIM | Siemens |  | Rel-7 |  |  |  |
| 200 | 37.1.8 | Stopped - Management of Legacy Equipment |  | 336d? | 2005-09-02 A | 2006-12-15 A | 100% | 2005-09-02 | 2006-12-15 | 336d? | finish no earlier than 2006-12-15 | S5 | 2688h | 2688h | OAM7-NIM | Siemens |  | Rel-7 |  |  |  |
| 201 | 37.1.9 | Stopped - Rules for Vendor Specific Extensions |  | 400d? | 2005-09-02 A | 2007-03-15 A | 100% | 2005-09-02 | 2007-03-15 | 400d? | finish no earlier than 2007-03-15 | S5 | 3200h | 3200h | OAM7-NIM | Siemens |  | Rel-7 |  |  |  |
| 202 | 37.1.10 | Backward and Forward Compatibility of IRP systems |  | 465d? | 2005-09-02 A | 2007-06-14 A | 100% | 2005-09-02 | 2007-06-14 | 465d? | finish no earlier than 2007-06-14 | S5 | 3720h | 3720h | OAM7-NIM | Ericsson |  | Rel-7 |  |  |  |
| 203 | 37.1.11 | Repeater Network Resource Model (NRM) definition |  | 214d? | 2006-02-13 A | 2006-12-07 A | 100% | 2006-02-13 | 2006-12-07 | 214d? | finish no earlier than 2006-12-07 | S5 | 1712h | 1712h | OAM7-NIM | China Mobile |  | Rel-7 |  |  |  |
| 204 | 37.1.12 | UTRAN radio channel power monitoring |  | 284d? | 2006-02-13 A | 2007-03-15 A | 100% | 2006-02-13 | 2007-03-15 | 284d? | finish no earlier than 2007-03-15 | S5 | 2272h | 2272h | OAM7-NIM | China Mobile |  | Rel-7 |  |  |  |
| 205 | 37.1.13 | Notification XML Schema |  | 71d? | 2006-12-07 A | 2007-03-15 A | 100% | 2006-12-07 | 2007-03-15 | 71d? | finish no earlier than 2007-03-15 | S5 | 568h | 568h | OAM7-NIM | Huawei |  | Rel-7 |  |  |  |

Notes:
- 182: WID approved SA#27. Revised at SA#28. WID update approved at SA#32 / Text3: 22.101, 23.228, 32.250, 32.260, 32.299, 32.298
- 183: Text3: 23.806
- 185: Text3: 23.206
- 186: Text3: new TS, 24.229, 23.008, 23.009, 23.078, 29.078, 29.163, 29.228, 29.229, 29.230, 29.278, 29.328, 29.329
- 187: Text3: new TS, 24.206 and 24.216
- 188: Text3: 23.003
- 189: Text3: 29.163
- 190: 03/2006 SA#31 WID approved / Text3: 32.250, 32.260, 32.298, 32.299
- 193: Text3: 32.731/2/3/5, 32.631/2/3/5
- 194: Text3: TR 32.806/814, 32.101
- 195: Text3: TR 32.811
- 196: Text3: 32.391/2/3/5
- 197: Text3: 32.307/317/607/667/665, 32.101, 32.175
- 198: Text3: 32.372/3/5, 32.111,32.30x,32.32x,32.33x,32.34x,32.35x,32.36x,32.41x,32.60x,32.61x,32.66x
- 199: Text3: 32.381/2/3/5
- 200: Text3: new TS 32.xxx
- 201: Request to TSG#35 to STOP the WI / Text3: 32.62n; For n = 1 to 5
- 202: Submit Exception Sheet for TSG#35 Approval / Text3: TS 32.154
- 203: Text3: 32.721/2/3/5
- 204: Text3: 32.405, 32.64n; For n = 1 to 5
- 205: 12/2006 SA#34 WID approved / Text3: New TS 32.325/345/365/415, CR to 32.335/615/665

| ID | WBS | Task | Type | Duration | Start | Finish | Complete | Baseline start | Baseline finish | Baseline duration | Constraint | Resources | Work | Actual work | Text1 | Text6 | Text4 | Text7 | Text12 | Text5 | Text8 |
| --- | --- | --- | --- | --- | --- | --- | --- | --- | --- | --- | --- | --- | --- | --- | --- | --- | --- | --- | --- | --- | --- |
| 206 | 37.2 | **Performance Management** |  | 465d? | 2005-09-02 A | 2007-06-14 A | 100% | 2005-09-02 | 2007-06-14 | 465d? |  | S5 | 22992h | 22992h | OAM7-PM | Rel-7 |  |  |  |  |  |
| 207 | 37.2.1 | Performance measurements definition for CN CS |  | 400d? | 2005-09-02 A | 2007-03-15 A | 100% | 2005-09-02 | 2007-03-15 | 400d? | finish no earlier than 2007-03-15 | S5 | 3200h | 3200h | OAM7-PM | Rel-7 | China Mobile |  |  |  |  |
| 208 | 37.2.2 | Enhancement UTRAN performance measurements definition |  | 465d? | 2005-09-02 A | 2007-06-14 A | 100% | 2005-09-02 | 2007-06-14 | 465d? | finish no earlier than 2007-06-14 | S5 | 3720h | 3720h | OAM7-PM | Rel-7 | China Mobile |  |  |  |  |
| 209 | 37.2.3 | Add TDD specific counters in Performance measurement |  | 330d? | 2005-09-02 A | 2006-12-07 A | 100% | 2005-09-02 | 2006-12-07 | 330d? | finish no earlier than 2006-12-15 | S5 | 2640h | 2640h | OAM7-PM | Rel-7 | CATT |  |  |  |  |
| 210 | 37.2.4 | ATM bearer network Performance measurements |  | 400d? | 2005-09-02 A | 2007-03-15 A | 100% | 2005-09-02 | 2007-03-15 | 400d? | finish no earlier than 2007-03-15 | S5 | 3200h | 3200h | OAM7-PM | Rel-7 | ZTE |  |  |  |  |
| 211 | 37.2.5 | Performance measurements definition for IMS |  | 465d? | 2005-09-02 A | 2007-06-14 A | 100% | 2005-09-02 | 2007-06-14 | 465d? | finish no earlier than 2007-06-14 | S5 | 3720h | 3720h | OAM7-PM | Rel-7 | China Mobile |  |  |  |  |
| 212 | 37.2.6 | HSDPA performance measurements |  | 349d? | 2006-02-13 A | 2007-06-14 A | 100% | 2006-02-13 | 2007-06-14 | 349d? | finish no earlier than 2007-06-14 | S5 | 2792h | 2792h | OAM7-PM | Rel-7 | China Mobile |  |  |  |  |
| 213 | 44.5 | **Trace Management** |  | 472.86d? | 2005-09-02 A | 2007-06-26 A | 100% | 2004-02-16 | 2007-06-15 | 870d? |  | S5 | 14150.9h | 14150.9h | OAM7-Trace | Rel-7 | Vodafone | TSG |  |  |  |
| 214 | 37.3.1 | End-to-end Service Level tracing for IMS |  | 350d? | 2005-11-11 A | 2007-03-15 A | 100% | 2005-11-11 | 2007-03-15 | 350d? | finish no earlier than 2007-03-15 | S5 | 2800h | 2800h | OAM7-Trace | Rel-7 | Vodafone | TSG | SP-31 |  |  |
| 215 | 37.3.2 | Trace record content for UTRAN TDD |  | 330d? | 2005-09-02 A | 2006-12-07 A | 100% | 2005-09-02 | 2006-12-07 | 330d? | finish no earlier than 2006-12-07 | S5 | 2640h | 2640h | OAM7-Trace | Rel-7 | Nokia | TSG |  |  |  |
| 216 | 37.3.3 | IRP for Subscriber and Equipment Trace Management |  | 465d? | 2005-09-02 A | 2007-06-14 A | 100% | 2005-09-02 | 2007-06-14 | 465d? | finish no earlier than 2007-06-14 | S5 | 3720h | 3720h | OAM7-Trace | Rel-7 | Nokia | TSG |  |  |  |
| 217 | 37.3.4 | Deleted - SIP enhancements for trace | milestone | 0d? | 2007-06-15 A | 2007-06-26 A | 100% | 2004-02-16 | 2007-06-15 | 863.14d? | start no earlier than 2007-06-15 | C1 |  |  | OAM7-Trace | Rel-7 |  |  | CP-32 |  |  |
| 218 | 37.3.5 | Deleted - duplicated with UID 35063 - IRP for Subscriber and Equipment Trace Management |  | 336d? | 2005-09-02 A | 2006-12-15 A | 100% | 2005-09-02 | 2006-12-15 | 336d? | finish no earlier than 2006-12-15 | S5 | 2688h | 2688h | OAM7-Trace | Rel-7 | Nokia | TSG | SP-33 |  |  |
| 219 | 38 | Trust Requirements for Open Platforms in 3GPP |  | 499d? | 2005-01-03 A | 2006-11-30 A | 100% | 2005-01-03 | 2006-11-30 | 499d? | finish no earlier than 2006-11-30 | S3 | 3992h | 3992h | TrustOP | Rel-7 | Silke Holtmanns, Nokia | TSG |  | Silke.Holtmanns@NOKIA.COM | Michael |
| 220 | 39 | Development of UEA2 and UIA2 |  | 268d? | 2004-12-01 A | 2005-12-09 A | 100% | 2004-12-01 | 2005-12-09 | 268d? | finish no earlier than 2005-12-09 | S3 | 2144h | 2144h | AlgUEA2 | Rel-7 | Per Christoffersson, Teliasonera | TSG |  | per.christoffersson@teliasonera.com | Michael |
| 221 | 40 | Lawful Interception in the 3GPP Rel-7 architecture |  | 118d? | 2005-06-28 A | 2005-12-08 A | 100% | 2005-06-28 | 2005-12-08 | 118d? | start no earlier than 2005-06-28 | S3 | 944h | 944h | LI-7A | Rel-7 | Berthold Wilhelm, BMWI |  |  | berthold.wilhelm@regtp.de | Mike |
| 222 | 41 | **Support of Conversational Services in A/Gb mode via the PS domain** |  | 626d? | 2005-04-08 A | 2007-08-31 A | 100% | 2005-04-08 | 2007-05-18 | 551d? |  | GP | 15442.8h | 15442.8h | SCSAGB | Rel-7 | Gunnar Hedby, Ericsson |  |  | gunnar.hedby@ericsson.com | Paolo |
| 223 | 41.1 | Minimise the transfer delay between the SGSN and the MS |  | 604.95d? | 2005-04-08 A | 2007-08-31 A | 100% | 2005-04-08 | 2007-05-18 | 529.95d? | finish no earlier than 2007-08-31 | GP | 4839.6h | 4839.6h | SCSAGB-MTD | Rel-7 | Gunnar Hedby, Ericsson |  |  |  | Paolo |
| 224 | 41.2 | Definition of radio resource management functionality |  | 626d? | 2005-04-08 A | 2007-08-31 A | 100% | 2005-04-08 | 2007-05-18 | 551d? | finish no earlier than 2007-08-31 | G1 | 5008h | 5008h | SCSAGB-RRM | Rel-7 | Gunnar Hedby, Ericsson |  |  | gunnar.hedby@ericsson.com | Paolo |
| 225 | 41.3 | Support of Conversational Services in A/Gb mode via the PS domain – RLC Non-Persistent mode |  | 101d? | 2006-06-30 A | 2006-11-17 A | 100% | 2006-06-30 | 2006-11-17 | 101d? | finish no earlier than 2006-11-17 | G2 | 808h | 808h | SCSAGB-RLCNP | Rel-7 | Gunnar Hedby, Ericsson |  |  | gunnar.hedby@ericsson.com | Gert |
| 226 | 41.4 | Deleted- Radio Channel Support | milestone | 0d? | 2006-07-17 A | 2006-07-17 A | 100% | 2006-07-17 | 2006-07-17 | 0d? | start no earlier than 2006-07-17 | G2 |  |  | SCSAGB-RCHS | Rel-7 | Gunnar Hedby, Ericsson |  | SP-32 | gunnar.hedby@ericsson.com | Gert |
| 227 | 41.5 | Deleted- Modifications to FLO | milestone | 0d? | 2006-07-17 A | 2006-07-17 A | 100% | 2006-07-17 | 2006-07-17 | 0d? | start no earlier than 2006-07-17 | G2 |  |  | SCSAGB-FLO | Rel-7 | Gunnar Hedby, Ericsson |  | SP-32 | gunnar.hedby@ericsson.com | Gert |
| 228 | 42 | **Addition of new frequency band to GSM (T-GSM810)** |  | 626d? | 2005-04-08 A | 2007-08-31 A | 100% | 2005-04-08 | 2007-05-18 | 551d? |  | GP | 12112h | 12112h | TGSM810 | Rel-7 | Chen De, Huawei |  |  | chende@huawei.com | Paolo |
| 229 | 42.1 | Changes to core specification |  | 106d? | 2005-04-08 A | 2005-09-02 A | 100% | 2005-04-08 | 2005-09-02 | 106d? | finish no earlier than 2005-09-02 | GP | 848h | 848h | TGSM810-Core | Rel-7 | Chen De, Huawei |  |  | chende@huawei.com | Paolo |
| 230 | 42.2 | Changes to MS testing specification |  | 626d? | 2005-04-08 A | 2007-08-31 A | 100% | 2005-04-08 | 2007-05-18 | 551d? | finish no earlier than 2007-08-31 | G3 | 5008h | 5008h | TGSM810-MStest | Rel-7 | Chen De, Huawei |  |  | chende@huawei.com | Stoyan |
| 231 | 42.3 | Changes to BTS testing specification |  | 156d? | 2005-04-08 A | 2005-11-11 A | 100% | 2005-04-08 | 2005-11-11 | 156d? | finish no earlier than 2005-11-11 | G1 | 1248h | 1248h | TGSM810-BTStest | Rel-7 | Chen De, Huawei |  |  | chende@huawei.com | Paolo |

Notes:
- 207: Text3: 32.407, 32.408
- 208: Submit Exception Sheet for TSG#35 Approval / Text3: 32.405
- 209: Text3: 32.405
- 210: Text3: No impact on 32.404, 32.405, 32.406, 32.407
- 211: Submit Exception Sheet for TSG#35 Approval / Text3: 32.404,32.409,32.437, 32.632/3/4/5
- 212: Submit Exception Sheet for TSG#35 Approval / Text3: 32.405
- 214: 07/2005: OMA (Stage 1), Stage 2/3 SA5, CT1/3/4 / Text3: CR 32.101, 32.421/2/3.
- 215: Text3: CR 32.421/2/3.
- 216: Submit Exception Sheet for TSG#35 Approval / Text3: TS 32.441/2/3/5, CRs 32.632/3/5
- 217: combined with UID 11067
- 218: Text3: 32.421,32.422,32.423. 3 new TS 32.4x1,2,3
- 219: WID approved SA#26. Record created after SA#27 / Text3: 33.905
- 220: WID approved SA#26, Dependant on Funding Availability. Record created after SA#27 / Text3: 35.919, 35.215, 35.216, 35.217, 35.218
- 221: Text3: 33.106, 33.107, 33.108
- 222: Originally started Nov. 2003 as GP-030443
- 225: Text3: 43.955, 43.064, 44.060, 45.001, 45.002, 45.003, 45.005, 45.010, 51.010, 51.021
- 228: Text3: 45.005, 45.050, 24.008, 45.008, 45.001, 43.022, 43.030, 44.018, 44.060, 51.010-1, 51.021
- 229: Text3: 45.005, 45.050, 24.008, 45.008, 45.001, 43.022, 43.030, 44.018, 44.060
- 230: Text3: 51010-1
- 231: Text3: 51021

| ID | WBS | Task | Type | Duration | Start | Finish | Complete | Baseline start | Baseline finish | Baseline duration | Constraint | Resources | Work | Actual work | Text1 | Text4 | Text5 | Text6 | Text8 | Text3 | Text7 | Text12 |
| --- | --- | --- | --- | --- | --- | --- | --- | --- | --- | --- | --- | --- | --- | --- | --- | --- | --- | --- | --- | --- | --- | --- |
| 232 | 43 | **Handover of dedicated and shared resources while in dual transfer mode** |  | 421d? | 2005-04-08 A | 2006-11-17 A | 100% | 2005-04-08 | 2006-11-17 | 421d? |  | GP | 12672h | 12672h | HODSRDTM | Rami Vaittinen, Nokia | rami.vaittinen@nokia.com | Rel-7 | Paolo |  |  |  |
| 233 | 43.1 | Handover of dedicated and shared resources while in dual transfer mode |  | 321d? | 2005-04-08 A | 2006-06-30 A | 100% | 2005-04-08 | 2006-06-30 | 321d? | finish no earlier than 2006-06-30 | G2 | 2568h | 2568h | HODSRDTM-G2 | Rami Vaittinen, Nokia | rami.vaittinen@nokia.com | Rel-7 | Gert | 43.055, 44.018, 44.060 |  |  |
| 234 | 43.2 | MS Conformance Testing |  | 421d? | 2005-04-08 A | 2006-11-17 A | 100% | 2005-04-08 | 2006-11-17 | 421d? | finish no earlier than 2006-11-17 | G3 | 3368h | 3368h | HODSRDTM-Mstest | Rami Vaittinen, Nokia | rami.vaittinen@nokia.com | Rel-7 | Stoyan | 51-010 |  |  |
| 235 | 43.3 | BTS conformance testing |  | 421d? | 2005-04-08 A | 2006-11-17 A | 100% | 2005-04-08 | 2006-11-17 | 421d? | finish no earlier than 2006-11-17 | G1 | 3368h | 3368h | HODSRDTM-BTStest | Rami Vaittinen, Nokia | rami.vaittinen@nokia.com | Rel-7 | Paolo | 51.026 |  |  |
| 236 | 44 | Future GERAN Evolution |  | 486d? | 2005-04-08 A | 2007-02-16 A | 100% | 2005-04-08 | 2007-02-16 | 486d? | finish no earlier than 2007-02-16 | GP | 3888h | 3888h | FGE | Eddie Riddington, Nokia Corporation | eddie.riddington@nokia.com | Rel-7 | Paolo | 45.912 |  |  |
| 237 | 45 | 3G-324M Video Telephony Call Setup Times Improvements |  | 341d? | 2005-06-08 A | 2006-09-27 A | 100% | 2005-06-08 | 2006-09-27 | 341d? | finish no earlier than 2006-09-27 | S4 | 2728h | 2728h | VTCSTI | Edward Hall (Vodafone) | edward.hall@vodafone.co.uk | Rel-7 | Paolo | 26.911 |  |  |
| 238 | 46 | **Identification of Communication Services in IMS** |  | 620d? | 2005-05-02 A | 2007-09-14 A | 100% | 2005-05-02 | 2007-06-14 | 554d? |  | S2 | 13016h | 13016h | ServID | Stephen Terrill, Ericsson | stephen.terrill@ericsson.com | Rel-7 | Maurice | 22.228, 23.228, 23.203, 32.260, 32.298, 32.299 |  |  |
| 239 | 46.1 | TR for ICS |  | 232d? | 2005-05-02 A | 2006-03-21 A | 100% | 2005-05-02 | 2006-03-21 | 232d? | finish no earlier than 2006-03-20 | S2 | 1856h | 1856h | ServID |  |  | Rel-7 |  | 23.816 |  |  |
| 240 | 46.2 | Stage 2 of ICS |  | 144d? | 2005-11-11 A | 2006-05-31 A | 100% | 2005-11-11 | 2006-05-31 | 144d? | start no earlier than 2005-11-11 | S2 | 1152h | 1152h | ServID |  |  | Rel-7 |  |  |  |  |
| 241 | 46.3 | Stage 3 of ICS |  | 250d? | 2006-03-31 A | 2007-03-15 A | 100% | 2006-03-31 | 2007-03-15 | 250d? | finish no earlier than 2007-03-15 | C1 | 2000h | 2000h | ServID | Christer Holmberg (Ericsson) | christer.holmberg@ericsson.com | Rel-7 | Andrijana |  |  |  |
| 242 | 46.4 | SA5 Charging aspects of ServID |  | 381d? | 2006-03-31 A | 2007-09-14 A | 100% | 2006-03-31 | 2007-06-14 | 315d? | finish no earlier than 2007-09-14 | S5 | 3048h | 3048h | ServID | Orange | alain.bibas@orange-ft.com | Rel-7 | Adrian | 32.260, 32.298, 32.299 |  |  |
| 243 | 47 | **VoIMS bearer related enhancements** |  | 354d? | 2005-03-15 A | 2006-07-21 A | 100% | 2005-03-15 | 2006-07-21 | 354d? |  | S2 | 4303.2h | 4303.2h | VoIMS |  |  | Rel-7 |  |  |  |  |
| 244 | 47.1 | Improved support of IMS Realtime Services using HSDPA/HSUPA |  | 197d? | 2005-03-15 A | 2005-12-14 A | 100% | 2005-03-15 | 2005-12-14 | 197d? | start no earlier than 2005-03-15 | R2 | 1576h | 1576h | RANimp-IMSRealTime | Don Zelmer | don.zelmer@CINGULAR.COM | Rel-7 | MCC_RAN |  | TSG |  |
| 245 | 47.2 | Deleted - FS on enhancement of radio performance for VoIMS | milestone | 0d? | 2006-07-21 A | 2006-07-21 A | 100% | 2006-07-21 | 2006-07-21 | 0d? | start no earlier than 2006-07-21 | S2 |  |  | VoIMS | Laurence Lautier, Nortel Networks | lautierl@nortel.com | Rel-7 | Maurice | 23.807 |  | SP-32 |
| 246 | 48 | Performance Characterization of VoIMS over HSDPA\EUL channels |  | 713d? | 2005-03-15 A | 2007-12-06 A | 100% | 2005-03-15 | 2007-09-20 | 658d? | finish no earlier than 2007-12-06 | S4 | 5704h | 5704h | VoIMS-PCVoIMS | James W. McGowan (Alcatel-Lucent) | mcgowan@alcatel-lucent.com | Rel-7 | Paolo | 26.935 | TSG |  |
| 247 | 49 | **Optimizations for Multimedia Telephony over IMS** |  | 0d? | 2005-09-28 A | 2005-09-28 A | 100% | 2005-09-28 | 2005-09-28 | 0d? |  | S4 |  |  | OMTIMS | Olle Franceschi (Ericsson) | olle.franceschi@ericsson.com | Rel-7 | Paolo | 26.235, 26.236 |  |  |
| 248 | 49.1 | Stopped (deleted) - Characterisation of Adaptive Jitter Management Performance for VoIP Services | milestone | 0d? | 2005-09-28 A | 2005-09-28 A | 100% | 2005-09-28 | 2005-09-28 | 0d? | start no earlier than 2007-03-15 | S4 |  |  | OMTIMS-CAJMP | David Huo (Lucent Technologies) | dhuo@lucent.com | Rel-7 | Paolo |  |  |  |
| 249 | 50 | End-to-End Multimedia Services Performance Metrics |  | 382d? | 2005-09-28 A | 2007-03-15 A | 100% | 2005-09-28 | 2007-03-15 | 382d? | finish no earlier than 2007-03-15 | S4 | 3056h | 3056h | E2EMSPM | Zhang Yan (China Mobile) | zhangyanyf@chinamobile.com | Rel-7 | Paolo | 26.944 |  |  |
| 250 | 51 | **Supporting Globally Routable User Agent URIs in IMS** |  | 415d? | 2005-11-14 A | 2007-06-15 A | 100% | 2005-11-14 | 2007-06-15 | 415d? |  | S2 | 5600h | 5600h | GRUU | Adrian Buckley (Research In Motion) | abuckley@rim.com | Rel-7 | Maurice | 23.8XX, 22.228, 23.228, 23.218, 24.229 |  |  |
| 251 | 51.1 | TR on GRUU |  | 219d? | 2005-11-14 A | 2006-09-14 A | 100% | 2005-11-14 | 2006-09-14 | 219d? | finish no earlier than 2006-09-14 | S2 | 1752h | 1752h | GRUU |  |  | Rel-7 | Maurice |  |  |  |
| 252 | 51.2 | Stage 2 of GRUU |  | 65d? | 2006-07-03 A | 2006-09-29 A | 100% | 2006-07-03 | 2006-09-29 | 65d? | start no earlier than 2006-07-03 | S2 | 520h | 520h | GRUU |  |  | Rel-7 | Maurice |  |  |  |
| 253 | 51.3 | Stage 3 of GRUU |  | 271d? | 2006-06-02 A | 2007-06-15 A | 100% | 2006-06-02 | 2007-06-15 | 271d? | finish no earlier than 2007-06-15 | C1 | 2168h | 2168h | GRUU | Bernie McKibben, CableLabs |  | Rel-7 | Andrijana |  |  |  |
| 254 | 52 | ISIM API for Java Card |  | 620d? | 2005-03-14 A | 2007-07-27 A | 100% | 2005-03-14 | 2005-12-16 | 200d? | finish no earlier than 2007-07-27 | C6 | 4960h | 4960h | APIJAVA | Sebastian Hans, Sun Microsystems Ltd. |  | Rel-7 | Gaby | 31.103, TS 102 241 |  |  |
| 255 | 53 | NDS Authentication Framework Extension for TLS |  | 50d? | 2006-09-28 A | 2006-12-06 A | 100% | 2006-09-28 | 2006-12-06 | 50d? | finish no earlier than 2006-09-28 | S3 | 400h | 400h | NDSAFTLS | Tiina Koskinen (Nokia) | tiina.s.koskinen@nokia.com | Rel-7 | Michael | 33.310 |  |  |

Notes:
- 232: Started at GERAN#24
- 233: Started at GERAN#24
- 234: Stopped, no work done
- 235: Stopped, no work done
- 238: WID approved SA#28. Updated WID approved SA#32
- 241: end date updated by CT1-chairman after CT#33
- 242: 03/2006 SA#31 WID approved
- 243: Created by MCC to group all VoIMS related items, after consultation of chairs
- 245: WID approved SA#28: SA2#52: CLOSED - To be removed from the work plan
- 247: Completed
- 248: Stopped at SA#35
- 250: Approved at SP#29
- 251: Abandomned
- 252: S2#52: "GURU" corrected to "GRUU"
- 253: S2#52: "GURU" corrected to "GRUU"
- 254: reported complete when checked after CT6#44
- 255: TLS profile is moved to Rel-8

| ID | WBS | Task | Duration | Start | Finish | Complete | Baseline start | Baseline finish | Baseline duration | Constraint | Resources | Work | Actual work | Text1 | Text6 | Text4 | Text5 | Text8 | Text7 |
| --- | --- | --- | --- | --- | --- | --- | --- | --- | --- | --- | --- | --- | --- | --- | --- | --- | --- | --- | --- |
| 256 | 54 | **Rel7 Security enhancements** | 319d? | 2005-09-12 A | 2006-11-30 A | 100% | 2005-09-12 | 2006-11-30 | 319d? |  | S3 | 9336h | 9336h | SEC7 | Rel-7 |  |  |  |  |
| 257 | 54.1 | HTTPS connection between a UICC and a NAF | 1d? | 2005-09-12 A | 2005-09-12 A | 100% | 2005-09-12 | 2005-09-12 | 1d? | start no earlier than 2005-09-12 | S3 | 8h | 8h | SEC7-HSUN | Rel-7 | Jacques Seif (Gemalto) | JSeif@axalto.com |  |  |
| 258 | 54.2 | 2G GBA: 2G SIM usage in 3GPP GAA framework | 61d? | 2005-09-12 A | 2005-12-05 A | 100% | 2005-09-12 | 2005-12-05 | 61d? | finish no earlier than 2005-12-05 | S3 | 488h | 488h | SEC7-2GGBA | Rel-7 | Silke Holtmanns (Nokia) | Silke.Holtmanns@nokia.com |  |  |
| 259 | 54.3 | Generic Authentication Architecture usage extensions and optimisations | 319d? | 2005-09-12 A | 2006-11-30 A | 100% | 2005-09-12 | 2006-11-30 | 319d? | finish no earlier than 2006-11-30 | S3 | 2552h | 2552h | GAA2 | Rel-7 | Silke Holtmanns (Nokia) | Silke.Holtmanns@nokia.com |  |  |
| 260 | 54.4 | **SS7 TCAP security Gateway** | 241d? | 2005-09-12 A | 2006-08-14 A | 100% | 2005-09-12 | 2006-08-14 | 241d? |  | S3 | 3736h | 3736h | SEC7-NDS-TCAPsec | Rel-7 | Marc Blommaert (Siemens) | marc.blommaert@siemens.com |  |  |
| 261 | 54.4.1 | SA3 aspects of SEC7-NDS-TCAPsec | 130d? | 2005-09-12 A | 2006-03-10 A | 100% | 2005-09-12 | 2006-03-10 | 130d? | finish no earlier than 2006-03-10 | S3 | 1040h | 1040h | SEC7-NDS-TCAPsec-SA3 | Rel-7 | Marc Blommaert (Siemens) | marc.blommaert@siemens.com |  |  |
| 262 | 54.4.2 | TCAPsec Gateway | 96d? | 2006-04-03 A | 2006-08-14 A | 100% | 2006-04-03 | 2006-08-14 | 96d? | start no earlier than 2006-04-01 | C4 | 768h | 768h | SEC7-NDS-TCAPsec-CT4 | Rel-7 | Ulrich Wiehe, Siemens | Ulrich.wiehe@gksag.de | Kimmo |  |
| 263 | 55 | Key establishment between a UICC and a terminal | 201.45d? | 2005-12-07 A | 2006-09-28 A | 100% | 2005-12-07 | 2006-09-28 | 201.45d? | finish no earlier than 2006-09-28 | S3 | 1611.6h | 1611.6h | KeyEstUTerm | Rel-7 | Mireille Pauliac (Gemalto) | mireille.pauliac@gemplus.com |  |  |
| 264 | 56 | Key establishment between a UICC hosting device and a remote device | 235d? | 2006-12-06 A | 2007-10-30 A | 100% | 2006-12-06 | 2007-10-30 | 235d? | finish no earlier than 2007-10-30 | S3 | 1880h | 1880h | PNM | Rel-7 | Vesa Lehtovirta (Ericsson) | Vesa.Lehtovirta@ericsson.com | Michael |  |
| 265 | 57 | **Mobile Station Receive Diversity (DARP Phase II)** | 526d? | 2005-11-11 A | 2007-11-16 A | 100% | 2005-11-11 | 2007-08-31 | 471d? |  | GP | 16360h | 16360h | MSRD2 | Rel-7 | Kent Pedersen, Nokia Corporation (ETSI) | kent.pedersen@nokia.com | Paolo |  |
| 266 | 57.1 | Performance Requirements for Mobile Station Receive Diversity, DARP Phase II | 331d? | 2005-11-11 A | 2007-02-16 A | 100% | 2005-11-11 | 2007-02-16 | 331d? | finish no earlier than 2007-02-16 | GP | 2648h | 2648h | MSRD2-PerfReq | Rel-7 | Kent Pedersen, Nokia Corporation (ETSI) | kent.pedersen@nokia.com | Paolo |  |
| 267 | 57.2 | Capability signalling of Mobile Station Receive Diversity, DARP Phase II | 331d? | 2005-11-11 A | 2007-02-16 A | 100% | 2005-11-11 | 2007-02-16 | 331d? | finish no earlier than 2007-02-16 | GP | 2648h | 2648h | MSRD2-CapSig | Rel-7 | Kent Pedersen, Nokia Corporation (ETSI) | kent.pedersen@nokia.com | Paolo, Gert |  |
| 268 | 57.3 | Test Scenarios for Mobile Station Receive Diversity, DARP Phase II | 331d? | 2005-11-11 A | 2007-02-16 A | 100% | 2005-11-11 | 2007-02-16 | 331d? | finish no earlier than 2007-02-16 | GP | 2648h | 2648h | MSRD2-TestSc | Rel-7 | Kent Pedersen, Nokia Corporation (ETSI) | kent.pedersen@nokia.com | Paolo |  |
| 269 | 57.4 | MS conformance test of DARP Phase II (MSRD) | 526d? | 2005-11-11 A | 2007-11-16 A | 100% | 2005-11-11 | 2007-08-31 | 471d? | finish no earlier than 2007-11-16 | GP | 4208h | 4208h | MSRD2-Msconf | Rel-7 | Kent Pedersen, Nokia Corporation (ETSI) | kent.pedersen@nokia.com | Paolo, Stoyan |  |
| 270 | 58 | **MBMS Enhancements** | 625d? | 2005-07-11 A | 2007-11-30 A | 100% | 2005-07-11 | 2007-09-10 | 566d? |  | S1 | 10844.6h | 10844.6h | MBMSE | Rel-7 | Liu Hong, China Mobile | liuhongyfw@chinamobile.com | Mike |  |
| 271 | 58.1 | Stage 1 of MBMSE | 109d? | 2005-07-11 A | 2005-12-08 A | 100% | 2005-07-11 | 2005-12-08 | 109d? | finish no earlier than 2005-12-08 | S1 | 872h | 872h | MBMSE | Rel-7 | Liu Hong, China Mobile | liuhongyfw@chinamobile.com | Mike |  |
| 272 | 58.2 | closed - MBMS FDD Physical layer Enhancements | 117.29d? | 2006-12-15 A | 2007-06-04 A | 100% | 2006-12-15 | 2007-06-04 | 117.29d? | finish no earlier than 2007-06-04 | R1 | 938.32h | 938.32h | MBMSE-RANPhysFDD | Rel-7 | Lars Lindbom | Lars.Lindbom@ericsson.com |  |  |
| 273 | 58.3 | closed - MBMS TDD Physical layer Enhancements | 117.29d? | 2006-12-15 A | 2007-06-04 A | 100% | 2006-12-15 | 2007-06-04 | 117.29d? | finish no earlier than 2007-06-04 | R1 | 938.32h | 938.32h | MBMSE-RANPhysTDD | Rel-7 | Nicholas Anderson |  |  |  |
| 274 | 58.4 | closed - MBMS Low Chip Rate TDD Physical Layer Enhancement | 127d? | 2007-03-16 A | 2007-09-10 A | 100% | 2007-03-16 | 2007-09-10 | 127d? | finish no earlier than 2007-09-10 | R1 | 1016h | 1016h | MBMSE-RANPhysLCRTDD | Rel-7 |  |  |  |  |
| 275 | 58.5 | MBMS Mz interface | 260d? | 2006-12-04 A | 2007-11-30 A | 100% | 2006-12-04 | 2007-05-11 | 115d? | finish no earlier than 2007-05-11 | C3 | 2080h | 2080h | MBMSMz | Rel-7 | Deng Tingting, Huawei | ttdeng@huawei.com | Seung Don |  |
| 276 | 59 | MBMS User Service Extensions | 392d? | 2005-12-07 A | 2007-06-07 A | 100% | 2005-12-07 | 2007-06-07 | 392d? | finish no earlier than 2007-06-07 | S4 | 3136h | 3136h | MBMSUSE | Rel-7 | Thorsten Lohmar (Ericsson) | Thorsten.Lohmar@ericsson.com | Paolo |  |
| 277 | 60 | IMS Support of Conferencing and Messaging Group Management | 355d? | 2005-11-04 A | 2007-03-15 A | 100% | 2005-11-04 | 2007-03-15 | 355d? | finish no earlier than 2007-03-15 | C1 | 2840h | 2840h | IMSconf | Rel-7 | Keith Drage (Alcatel-Lucent) | drage@alcatel-lucent.com | Andrijana |  |
| 278 | 61 | **Selective Disabling of UE Capabilities** | 624.36d? | 2005-01-24 A | 2007-06-15 A | 100% | 2005-01-24 | 2007-06-15 | 624.36d? |  | S1 | 12036.8h | 12036.8h | SDoUE | Rel-7 | Nigel Barnes (Motorola Ltd) | Nigel.Barnes@motorola.com | Michael | TSG |
| 279 | 61.1 | Stage 1 of SDoUE | 393.6d? | 2005-01-24 A | 2006-12-08 A | 100% | 2005-01-24 | 2006-12-08 | 393.6d? | finish no earlier than 2006-12-08 | S1 | 3148.8h | 3148.8h | SDoUE-CRs | Rel-7 | Nigel Barnes (Motorola Ltd) | Nigel.Barnes@motorola.com | Michael | TSG |
| 280 | 61.2 | TR on different possible architectures | 195d? | 2005-03-21 A | 2005-12-16 A | 100% | 2005-03-21 | 2005-12-16 | 195d? | finish no earlier than 2005-12-16 | S2 | 1560h | 1560h | SDoUE-FS | Rel-7 |  |  | Maurice |  |
| 281 | 61.3 | Stage 3 of SDoUE | 331d? | 2006-03-10 A | 2007-06-15 A | 100% | 2006-03-10 | 2007-06-15 | 331d? | finish no earlier than 2007-06-15 | C1 | 2648h | 2648h | SDoUE | Rel-7 | Christian Herrero (Ericsson) | christian.herrero@ericsson.com | Andrijana |  |

Notes:
- 257: Text3: 33.222, 24.109, 33.918
- 258: Text3: 33.220, 33.920
- 259: Except TS 33.223 / Text3: 33.220, 29.109, 24.109, 33.223, (33.223 goes to R8)
- 260: Text3: 33.200, 33.204
- 261: Text3: 33.200, 33.204
- 262: Study WI... / Text3: new TS 29.204
- 263: Text3: 33.110
- 264: Text3: 33.259
- 265: Text3: 24.008, 45.005, 51.010
- 266: Text3: 45.005
- 267: Text3: 24.008
- 268: Text3: 45.005
- 269: Text3: 51.010
- 271: Strucutre created by MCC to include RAN aspects under SA1 Feature
- 272: closed at 78% / Text3: 25.211, 25.212, 25.213, 25.101, 25.104, 25.331, 25.433, 25.346, 25.306
- 273: closed at 94% / Text3: 25.346, 25.221, 25.222, 25.223, 25.224, 25.306, 25.331, 25.402, 25.433, 25.102, 25.105, 25.123
- 274: closed at 75%
- 275: Text3: 29.061
- 276: Text3: 26.346, 26.946
- 277: Text3: 24.147, 24.229
- 278: Moved from FS section Feb 06 / Text3: 22.xxx
- 279: Moved from FS section Feb 06 / Text3: 22.011, 22.060, 23.060, 24.008, 23.805, 24.305
- 280: Moved from FS section Feb 06 / Text3: 23.805
- 281: Text3: New TS 24.305

| ID | WBS | Task | Type | Duration | Start | Finish | Complete | Remaining | Baseline start | Baseline finish | Baseline duration | Total slack | Constraint | Resources | Work | Actual work | Text1 | Text4 | Text5 | Text6 | Text8 | Text7 |
| --- | --- | --- | --- | --- | --- | --- | --- | --- | --- | --- | --- | --- | --- | --- | --- | --- | --- | --- | --- | --- | --- | --- |
| 282 | 62 | **Multimedia Telephony Service for IMS** |  | 357d? | 2006-02-01 A | 2007-06-15 A | 100% |  | 2006-03-10 | 2007-06-15 | 330d? |  |  | S1 | 8736h | 8736h | MTSI | Supporting Companies: | peter.bleckert @ericsson.com | Rel-7 | Patrick |  |
| 283 | 62.1 | Stage 1 of MTSI |  | 173d? | 2006-02-01 A | 2006-09-29 A | 100% |  | 2006-03-15 | 2006-12-06 | 191d? |  | start no earlier than 2006-02-01 | S1 | 1384h | 1384h | MTSI-REQ | Peter Bleckert, Ericsson | peter.bleckert @ericsson.com | Rel-7 | Alain |  |
| 284 | 62.2 | Deleted - duplicates UID7039 - IMS Multimedia Telephony Service | milestone | 0d? | 2007-06-15 A | 2007-06-15 A | 100% |  | 2006-02-01 | 2006-09-29 | 173d? |  | start no earlier than 2007-06-15 | S1 |  |  | MMTEL | Peter Bleckert, Ericsson | peter.bleckert @ericsson.com | Rel-7 | Mike |  |
| 285 | 62.3 | Stage 3 of MTSI |  | 330d? | 2006-03-10 A | 2007-06-15 A | 100% |  | 2006-03-10 | 2007-06-15 | 330d? |  | finish no earlier than 2007-06-15 | C1 | 2640h | 2640h | MTSI | Christer Holmberg (Ericsson) | christer.holmberg@ericsson.com | Rel-7 | Andrijana |  |
| 286 | 62.4 | Media handling and interaction in MTSI |  | 262d? | 2006-03-15 A | 2007-03-15 A | 100% |  | 2006-03-15 | 2007-03-15 | 262d? |  | finish no earlier than 2007-03-15 | S4 | 2096h | 2096h | MTSI-MHI | Olle Franceschi (Ericsson) | olle.franceschi@ericsson.com | Rel-7 | Paolo |  |
| 287 | 63 | TISPAN requirements for Multimedia Telephony with PSTN/ISDN simulation services |  | 58d? | 2007-09-18 A | 2007-12-06 A | 100% |  |  |  |  |  | start no earlier than 2007-09-18 | S1 | 464h | 464h | TMMTEL7 |  |  | Rel-7 |  |  |
| 288 | 64 | **Multimedia interworking between IMS and CS networks** |  | 571d? | 2005-09-23 A | 2007-11-30 A | 100% |  | 2005-09-23 | 2007-05-11 | 426d? |  |  | C3 | 9528.01h | 9528.01h | MIWIMS | Nico Gabriele, Vodafone UK | nico.gabriele@vodafone.com | Rel-7 | Seung Don |  |
| 289 | 64.1 | Note: Stages 1 and 2 defined in earlier Release |  | 49d? | 2005-09-23 A | 2005-11-30 A | 100% |  | 2005-09-23 | 2005-11-30 | 49d? |  | start no earlier than 2005-09-23 | S2 | 392h | 392h | MIWIMS |  |  | Rel-7 |  |  |
| 290 | 64.2 | Stage 3 of MW-IMS |  | 571d? | 2005-09-23 A | 2007-11-30 A | 100% |  | 2005-09-23 | 2007-05-11 | 426d? |  | finish no earlier than 2007-09-14 | C3 | 4568h | 4568h | MWIMS-St3 |  |  | Rel-7 |  |  |
| 291 | 65 | **Network selection enhancements** |  | 328d? | 2006-03-15 A | 2007-06-15 | 99% | 0d? | 2006-03-15 | 2007-06-15 | 328d? | 0d |  | S1 | 6320h | 4340h | NSP-CR | Chris Friel, O2 | chris.friel@o2.com | Rel-7 | Michael |  |
| 292 | 65.1 | Stage 1 of NSP |  | 191d? | 2006-03-15 A | 2006-12-06 A | 100% |  | 2006-03-15 | 2006-12-06 | 191d? |  | start no earlier than 2006-03-15 | S1 | 1528h | 1528h | NSP-TS | Chris Friel, O2 | chris.friel@o2.com | Rel-7 | Michael |  |
| 293 | 65.2 | Procedural aspects of NSP |  | 271d? | 2006-06-02 A | 2007-06-15 A | 100% |  | 2006-06-02 | 2007-06-15 | 271d? |  | finish no earlier than 2007-06-15 | C1 | 2168h | 2168h | NSP-CR | Andrew Howell (Motorola) | andrew.howell@motorola.com | Rel-7 | Andrijana |  |
| 294 | 66 | **Interoperability between VGCS/VBS and A/Gb flexibility** |  | 253d? | 2006-03-22 A | 2007-03-09 A | 100% |  | 2006-03-22 | 2007-03-09 | 253d? |  |  | C1 | 5320h | 5320h | VGCSFlex | Robert Zaus (Siemens) | robert.zaus@siemens.com | Rel-7 | Andrijana |  |
| 295 | 66.1 | CT1 aspects of VGCSFlex |  | 159d? | 2006-03-22 A | 2006-10-30 A | 100% |  | 2006-03-22 | 2006-10-30 | 159d? |  | finish no earlier than 2006-10-30 | C1 | 1272h | 1272h | VGCSFlex |  |  | Rel-7 |  |  |
| 296 | 66.2 | CT4 aspects of VGCSFlex |  | 253d? | 2006-03-22 A | 2007-03-09 A | 100% |  | 2006-03-22 | 2007-03-09 | 253d? |  | finish no earlier than 2007-03-09 | C4 | 2024h | 2024h | VGCSFlex-c4 |  |  | Rel-7 |  |  |
| 297 | 67 | **One Tunnel solution for Optimisation of Packet Data Traffic** |  | 418d? | 2006-03-27 A | 2007-10-31 A | 100% |  | 2006-03-27 | 2007-10-31 | 418d? |  |  | S2 | 7048h | 7048h | OPTUNEL | Antti Pasanen (Nokia) |  | Rel-7 | Maurice |  |
| 298 | 67.1 | Discontinued - Stage 2 Study for One Tunnel solution |  | 125d? | 2006-03-27 A | 2006-09-15 A | 100% |  | 2006-03-27 | 2006-09-15 | 125d? |  | finish no earlier than 2005-09-12 | S2 | 1000h | 1000h | OPTUNEL-Study | Antti Pasanen (Nokia) | antti.j.pasanen@nokia.com | Rel-7 | Maurice | TSG |
| 299 | 67.2 | One Tunnel Deployment Guideline |  | 268d? | 2006-10-23 A | 2007-10-31 A | 100% |  | 2006-10-23 | 2007-10-31 | 268d? |  | finish no earlier than 2007-10-31 | S2 | 2144h | 2144h | OPTUNEL-Guide | Lan Liu (Huawei) | lan.liu@huawei.com | Rel-7 | Maurice | TSG |
| 300 | 67.3 | Stage 2 specification for One Tunnel solution |  | 70d? | 2006-09-11 A | 2006-12-15 A | 100% |  | 2006-09-11 | 2006-12-15 | 70d? |  | finish no earlier than 2006-12-15 | S2 | 560h | 560h | OPTUNEL-Stage2 | Antti Pasanen (Nokia) | antti.j.pasanen@nokia.com | Rel-7 | Maurice | TSG |
| 301 | 68 | **Downlink Dual Carrier** |  | 741d? | 2006-01-20 A | 2008-11-21 | 51% | 365.28d? | 2006-01-20 | 2007-08-31 | 421d? | 0d |  | GP | 17028.8h | 6060.8h | GDCDL | Leonardo Provvedi, Nokia Siemens Networks | leonardo.provvedi@roke.co.uk | Rel-7 | Paolo |  |
| 302 | 68.1 | Downlink Dual Carrier Stage 2 |  | 116d? | 2006-01-20 A | 2006-06-30 A | 100% |  | 2006-01-20 | 2006-06-30 | 116d? |  | finish no earlier than 2006-06-30 | G1 | 928h | 928h | GDCDL-Stage2 | Leonardo Provvedi, Nokia Siemens Networks | leonardo.provvedi@roke.co.uk | Rel-7 | Paolo |  |
| 303 | 68.2 | Downlink Dual Carrier Stage 3 |  | 421d? | 2006-01-20 A | 2007-08-31 A | 100% |  | 2006-01-20 | 2007-07-31 | 398d? |  | finish no earlier than 2007-08-31 | G2; G1 | 4244.8h | 4244.8h | GDCDL-Stage3 | Leonardo Provvedi, Nokia Siemens Networks | leonardo.provvedi@roke.co.uk | Rel-7 | Gert, Paolo |  |
| 304 | 68.3 | Downlink Dual Carrier – MS Conformance Test |  | 741d? | 2006-01-20 A | 2008-11-21 | 15% | 630d? | 2006-01-20 | 2007-08-31 | 421d? | 0d | finish no earlier than 2008-11-21 | G3 | 5928h | 888h | GDCDL-MStest | Leonardo Provvedi, Nokia Siemens Networks | leonardo.provvedi@roke.co.uk | Rel-7 | Stoyan |  |
| 305 | 69 | Support of SIGTRAN in GERAN |  | 116d? | 2006-01-20 A | 2006-06-30 A | 100% |  | 2006-01-20 | 2006-06-30 | 116d? |  | finish no earlier than 2006-06-30 | GP | 928h | 928h | GSIGT | Peter Ostrup, Ericsson | peter.ostrup@ericsson.com | Rel-7 | Paolo |  |
| 306 | 70 | Packet Switched Streaming Enhancements |  | 261d? | 2006-06-08 A | 2007-06-07 A | 100% |  | 2006-06-08 | 2007-06-07 | 261d? |  | finish no earlier than 2007-06-07 | S4 | 2088h | 2088h | PSSe | Olle Franceschi (Ericsson) | olle.franceschi@ericsson.com | Rel-7 | Paolo |  |

Notes:
- 283: previous version in SP-050387 / Text3: 22.173
- 284: Text3: 22.173
- 285: TS 24.173:IMS Multimedia telephony service and supplementary services / Text3: 24.173
- 286: Text3: 26.114
- 288: Moved from FS section Feb 06 / Text3: 29.163, 29.332
- 289: Moved from FS section Feb 06
- 290: Text3: 29.163
- 291: Text3: 22.101, 22.011, 23.122, 24.008, 25.304, 31.102, 45.008
- 292: Text3: 22.101, 22.011, 23.122, 24.008, 25.304, 31.102, 45.008
- 293: Text3: 23.122, 24.008, 31.102
- 294: Text3: 43.068, 43.069, 29.002
- 295: Text3: 43.068, 43.069
- 296: CT4#33: The work is 95% complited / Text3: 29.002
- 298: S2#52 CREATED. TR for Info SP-33. SP-34: S2 Report intention to discontinue TR / Text3: 23.809
- 299: S2#55 CREATED: SP-34 Approved and exception request granted until 03/07 / Text3: 23.9de
- 300: S2#52 CREATED / Text3: 23.060
- 301: Text3: 24.008, 43.055, 43.064, 44.018, 44.060, 45.001, 45.002, 45.005, 45.008, 51.010
- 302: Text3: 43.055, 43.064
- 303: Text3: 24.008, 44.018, 44.060, 45.001, 45.002, 45.005, 45.008
- 304: Text3: 51.010
- 305: Text3: 48.001, 48.006, 43.059, 49.031
- 306: Text3: 26.234, 26.244

| ID | WBS | Task | Type | Duration | Start | Finish | Complete | Remaining | Baseline start | Baseline finish | Baseline duration | Total slack | Constraint | Resources | Work | Actual work | Text1 | Text4 | Text5 | Text6 | Text8 | Text12 |
| --- | --- | --- | --- | --- | --- | --- | --- | --- | --- | --- | --- | --- | --- | --- | --- | --- | --- | --- | --- | --- | --- | --- |
| 307 | 71 | **Charging Management small Enhancements Rel-7** |  | 279d? | 2006-05-22 A | 2007-06-14 A | 100% |  | 2006-05-22 | 2007-06-14 | 279d? |  |  | S5 | 5952h | 5952h | CH7 | Orange | alain.bibas@francetelecom.com | Rel-7 | Adrian |  |
| 308 | 71.1 | Alternate Charged Party (ACP) for IMS |  | 279d? | 2006-05-22 A | 2007-06-14 A | 100% |  | 2006-05-22 | 2007-06-14 | 279d? |  | finish no earlier than 2007-06-14 | S5 | 2232h | 2232h | CH7-IMS-ACP | Lucent | njmazzarella@alcatel-lucent.com | Rel-7 |  |  |
| 309 | 71.2 | Align 3GPP Charging with OMA PoC Enabler Release 2.0 |  | 186d? | 2006-09-28 A | 2007-06-14 A | 100% |  | 2006-09-28 | 2007-06-14 | 186d? |  | finish no earlier than 2007-06-14 | S5 | 1488h | 1488h | CH7-PoC | Siemens | gerald.goermer@siemens.com | Rel-7 | Adrian |  |
| 310 | 72 | **Latency Reductions** |  | 306d? | 2006-06-30 A | 2007-08-31 A | 100% |  | 2006-06-30 | 2007-05-18 | 231d? |  |  | GP | 7344h | 7344h | LATRED | Håkan Persson, Ericsson | Hakan.Persson@Ericsson.com | Rel-7 | Paolo |  |
| 311 | 72.1 | Improved Ack/Nack reporting |  | 306d? | 2006-06-30 A | 2007-08-31 A | 100% |  | 2006-06-30 | 2007-05-18 | 231d? |  | finish no earlier than 2007-08-31 | G2 | 2448h | 2448h | LATRED-ACKNAR | Håkan Persson, Ericsson | Hakan.Persson@Ericsson.com | Rel-7 | Gert |  |
| 312 | 72.2 | Reduced TTI |  | 306d? | 2006-06-30 A | 2007-08-31 A | 100% |  | 2006-06-30 | 2007-05-18 | 231d? |  | finish no earlier than 2007-08-31 | G2 | 2448h | 2448h | LATRED-REDTTI | Håkan Persson, Ericsson | Hakan.Persson@Ericsson.com | Rel-7 | Gert |  |
| 313 | 73 | PS Handover between GERAN/UTRAN mode and GAN Mode |  | 166d? | 2006-06-30 A | 2007-02-16 A | 100% |  | 2006-06-30 | 2007-02-16 | 166d? |  | finish no earlier than 2007-02-16 | G2 | 1328h | 1328h | GUGAN | John Diachina, Ericsson | John.Diachina@Ericsson.com | Rel-7 | Gert |  |
| 314 | 74 | **CSI Terminating Session handling** |  | 267d? | 2006-06-08 A | 2007-06-15 A | 100% |  | 2006-06-08 | 2007-06-15 | 267d? |  |  | S2 | 4728h | 4728h | CSItermS | Osok Song (Samsung) |  | Rel-7 | Maurice |  |
| 315 | 74.1 | Stage 2 of CStermS |  | 192d? | 2006-06-08 A | 2007-03-02 A | 100% |  | 2006-06-08 | 2007-03-02 | 192d? |  | start no earlier than 2006-06-08 | S2 | 1536h | 1536h | CSItermS | Osok Song (Samsung) |  | Rel-7 | Maurice |  |
| 316 | 74.2 | Stage 3 of CStermS |  | 132d? | 2006-12-14 A | 2007-06-15 A | 100% |  | 2006-12-14 | 2007-06-15 | 132d? |  | finish no earlier than 2007-06-15 | C1 | 1056h | 1056h | CSItermS | Chen-Ho CHIN, Samsung | chenho.chin@samsung.com | Rel-7 | Andrijana |  |
| 317 | 74.3 | Deleted - duplicated with UID 340015 -Stage 3 CSI Terminating Session handling | milestone | 0d? | 2007-03-09 A | 2007-03-09 A | 100% |  | 2007-03-09 | 2007-03-09 | 0d? |  | start no earlier than 2007-03-09 | C1 |  |  | CSItermS | Chen-Ho CHIN, Samsung | chenho.chin@samsung.com | Rel-7 | Andrijana | CP-34 |
| 318 | 75 | High speed interface between the UICC and the ME |  | 311d? | 2006-09-22 A | 2007-11-30 A | 100% |  | 2006-09-22 | 2007-11-30 | 311d? |  | finish no earlier than 2007-11-30 | C6 | 2488h | 2488h | HSI | Jacques Seif, Gemalto | jacques.seif@GEMALTO.COM | Rel-7 | Gaby |  |
| 319 | 76 | Interworking between the 3GPP CS domain with BICC or ISUP as signalling protocol and external SIP-I networks |  | 311d? | 2006-09-22 A | 2007-11-30 A | 100% |  | 2006-09-22 | 2007-05-11 | 166d? |  | finish no earlier than 2007-09-14 | C3 | 2488h | 2488h | ExtSIPI | Thomas Belling, Siemens | thomas.belling@SIEMENS.COM | Rel-7 | Seung Don |  |
| 320 | 77 | **Higher Uplink performance for GERAN Evolution** |  | 441d? | 2006-09-08 A | 2008-05-16 | 54% | 201.4d? | 2006-09-08 | 2007-11-16 | 311d? | 135d |  | GP | 21296h | 9804.16h | HUGE | NSN, Ericsson) | eddie.riddington@nokia.com, stefan.g.eriksson@ericsson.com | Rel-7 | Paolo |  |
| 321 | 77.1 | Stage 2 of HUGE |  | 261d? | 2006-09-08 A | 2007-09-07 A | 100% |  | 2006-09-08 | 2007-05-18 | 181d? |  | finish no earlier than 2007-09-07 | G1 | 2088h | 2088h | HUGE-Stage2 | NSN, Ericsson) | eddie.riddington@nokia.com, stefan.g.eriksson@ericsson.com | Rel-7 | Paolo |  |
| 322 | 77.2 | Layer 1 Support of HUGE |  | 381d? | 2006-09-08 A | 2008-02-22 A | 100% |  | 2006-09-08 | 2007-05-18 | 181d? |  | finish no earlier than 2008-02-22 | G1 | 3048h | 3048h | HUGE-Layer1 | NSN, Ericsson) | eddie.riddington@nokia.com, stefan.g.eriksson@ericsson.com | Rel-7 | Paolo |  |
| 323 | 77.3 | Layer 2/3 Support of HUGE |  | 256d? | 2006-09-08 A | 2007-08-31 A | 100% |  | 2006-09-08 | 2007-05-18 | 181d? |  | finish no earlier than 2007-08-31 | G2 | 2048h | 2048h | HUGE-Layer23 | NSN, Ericsson) | eddie.riddington@nokia.com, stefan.g.eriksson@ericsson.com | Rel-7 | Gert |  |
| 324 | 77.4 | Performance requirements |  | 441d? | 2006-09-08 A | 2008-05-16 | 70% | 132.3d? | 2006-09-08 | 2007-05-18 | 181d? | 135d | finish no earlier than 2008-05-16 | G1 | 3528h | 2469.6h | HUGE-Perfreq | NSN, Ericsson) | eddie.riddington@nokia.com, stefan.g.eriksson@ericsson.com | Rel-7 | Paolo |  |
| 325 | 77.5 | MS Conformance Test |  | 441d? | 2006-09-08 | 2008-05-16 |  |  | 2006-09-08 | 2007-11-16 | 311d? | 135d | finish no earlier than 2008-05-16 | G3 | 3528h |  | HUGE-Mstest | NSN, Ericsson) | eddie.riddington@nokia.com, stefan.g.eriksson@ericsson.com | Rel-7 | Stoyan |  |
| 326 | 77.6 | BTS Conformance Test |  | 441d? | 2006-09-08 | 2008-05-16 |  |  | 2006-09-08 | 2007-11-16 | 311d? | 135d | finish no earlier than 2008-05-16 | G1 | 3528h |  | HUGE-BTStest | NSN, Ericsson) | eddie.riddington@nokia.com, stefan.g.eriksson@ericsson.com | Rel-7 | Paolo |  |
| 327 | 78 | Routeing of MT-SMs via the HPLMN |  | 71d? | 2006-12-01 A | 2007-03-09 A | 100% |  | 2006-12-01 | 2007-03-09 | 71d? |  | finish no earlier than 2007-03-09 | C4 | 568h | 568h | SMSviaH | Nick Russell, Vodafone UK | Nick.Russell@vodafone.com | Rel-7 | Kimmo |  |
| 328 | 79 | PDU multiplexing at Nb Interface with IP transport |  | 70d? | 2006-12-04 A | 2007-03-09 A | 100% |  | 2006-12-04 | 2007-03-09 | 70d? |  | start no earlier than 2006-12-04 | C3 | 560h | 560h | NbIPMux | Jean Rzeznik, Alcatel-Lucent | Jean.Rzeznik@alcatel-lucent.fr | Rel-7 | Seung Don |  |
| 329 | 80 | **REduced symbol Duration, Higher Order modulation and Turbo coding (RED HOT) for downlink** |  | 466d? | 2006-11-17 A | 2008-08-29 | 40% | 280.93d? | 2006-11-17 | 2008-02-15 | 326d? | 60d |  | GP | 15360h | 4675.06h | REDHOT | Ericsson, NSN, Marvell | stefan.g.eriksson@ericsson.com | Rel-7 | Paolo |  |
| 330 | 80.1 | Stage 2 for REDHOT |  | 206d? | 2006-11-17 A | 2007-08-31 A | 100% |  | 2006-11-17 | 2007-05-18 | 131d? |  | finish no earlier than 2007-08-31 | G1 | 1648h | 1648h | REDHOT-Stage2 | Ericsson, NSN, Marvell | stefan.g.eriksson@ericsson.com | Rel-7 | Paolo |  |
| 331 | 80.2 | Stage 3 for REDHOT |  | 391d? | 2006-11-17 A | 2008-05-16 | 95% | 19.55d? | 2006-11-17 | 2007-08-31 | 206d? | 135d | finish no earlier than 2008-05-16 | G1 | 3128h | 2971.6h | REDHOT-Stage3 | Ericsson, NSN, Marvell | stefan.g.eriksson@ericsson.com | Rel-7 | Paolo |  |
| 332 | 80.3 | MS Conformance Tests |  | 466d? | 2006-11-17 | 2008-08-29 |  |  | 2006-11-17 | 2008-02-15 | 326d? | 60d | finish no earlier than 2008-08-29 | G3 | 3728h |  | REDHOT-Mstest | Ericsson | stefan.g.eriksson@ericsson.com | Rel-7 | Stoyan |  |
| 333 | 80.4 | BTS Conformance Tests |  | 391d? | 2006-11-17 | 2008-05-16 |  |  | 2006-11-17 | 2007-11-16 | 261d? | 135d | finish no earlier than 2008-05-16 | G1 | 3128h |  | REDHOT-BTStest | Ericsson, NSN, Marvell | stefan.g.eriksson@ericsson.com | Rel-7 | Paolo |  |
| 334 | 81 | Mobile Termination whilst the MS is moving to another MSC |  | 60d? | 2007-03-09 A | 2007-05-31 A | 100% |  | 2007-03-09 | 2007-05-31 | 60d? |  | start no earlier than 2007-03-09 | C4 | 480h | 480h | MTmovMS | Bruno Landais Alcatel-Lucent | bruno.landais@alcatel-lucent.fr | Rel-7 |  |  |

Notes:
- 307: Text3: 32.2xy
- 308: Text3: 32.240, 32.260, 32.298, 32.299
- 309: 09/2006 SA#33 WID approved / Text3: 32.240, 32.272, 32.299, 32.298
- 310: Text3: 45.001, 45.002, 45.003, 45.005, 45.010, 43.055, 43.064, 44.060, 51.010-1, 51.021
- 311: Text3: 45.001, 45.002, 45.003, 45.005, 45.010, 43.055, 43.064, 44.060, 51.010-1, 51.021
- 312: Text3: 45.001, 45.002, 45.003, 45.005, 45.010, 43.055, 43.064, 44.060, 51.010-1, 51.021
- 313: Text3: 43.318, 44.318, 43.129, 25.306, 24.008, 44.060, 25.331, 51.010
- 314: Not to be confused with FS with same name / Text3: 23.228, 23.279
- 315: Created to dissociate Stage 2 line from feature line / Text3: 23.228, 23.279
- 316: WID approved in CT#34 / Text3: 24.229, 24.279
- 317: WID approved in CT#34 / Text3: 24.229, 24.179, 24.279
- 318: Following ETSI publication of TS 102 600, expected to be completed at CT6#45 / Text3: 31.101, 31.102, 31.103
- 319: Text3: new TS 29.164
- 320: Exception sheet in GP-071567 / Text3: 24.008, 43.055, 43.064, 44.018, 44.060, 45.001, 45.002, 45.003, 45.004, 45.005, 45.008, 45.010, 51.010, 51.021
- 321: Text3: 43.055, 43.064
- 322: Text3: 45.001, 45.002, 45.003, 45.004, 45.008
- 323: Text3: 24.008, 44.018, 44.060
- 324: Text3: 45.005
- 325: Text3: 51.010
- 326: Text3: 51.021
- 327: WID approved in CT#34 / Text3: 23.040, 29.002
- 328: 08/03/2007 08:00 / Text3: 29.414
- 329: Exception sheet in GP-071565 / Text3: 24.008, 43.064, 43.055, 44.018, 44.060, 45.001, 45.002, 45.003, 45.004, 45.005, 45.008, 51.010, 51.021
- 330: Text3: 43.055, 43.064
- 331: Text3: 24.008, 44.018, 44.060, 45.001, 45.002, 45.003, 45.004, 45.005, 45.008
- 332: Text3: 51.010
- 333: Text3: 51.021
- 334: Text3: 23.008, 23.012, 23.018, 23.078, 23.079, 29.002

| ID | WBS | Task | Type | Duration | Start | Finish | Complete | Baseline start | Baseline finish | Baseline duration | Total slack | Constraint | Resources | Work | Actual work | Text1 | Text6 | Text8 | Text4 | Text5 | Text12 | Text7 |
| --- | --- | --- | --- | --- | --- | --- | --- | --- | --- | --- | --- | --- | --- | --- | --- | --- | --- | --- | --- | --- | --- | --- |
| 335 | 82 | **Maintenance of TISPAN release 1 common IMS** |  | 58d? | 2007-09-18 A | 2007-12-06 A | 100% |  |  |  |  |  | S2 | 1392h | 1392h | MCIMSTR1 | Rel-7 | Alain |  |  |  |  |
| 336 | 82.1 | SA1 aspects of MCIMSTR1 |  | 58d? | 2007-09-18 A | 2007-12-06 A | 100% |  |  |  |  | finish no earlier than 2007-12-06 | S1 | 464h | 464h | MCIMSTR1-S1 | Rel-7 |  | Marco De Luca (Telecom Italia) |  |  |  |
| 337 | 82.2 | SA2 aspects of MCIMSTR1 |  | 58d? | 2007-09-18 A | 2007-12-06 A | 100% |  |  |  |  | finish no earlier than 2007-12-06 | S2 | 464h | 464h | MCIMSTR1-S2 | Rel-7 |  | Raymond Forbes (LM Ericsson) |  |  |  |
| 338 | 83 | (Small) Technical Enhancements and Improvements for Rel-7 | milestone | 0d? | 2007-03-26 A | 2007-03-26 A | 100% | 2000-01-03 | 2007-03-26 | 1886d? |  | start no earlier than 2007-03-26 | All |  |  | TEI7 | Rel-7 |  |  |  |  |  |
| 339 | 84 | **Deleted - PS domain and IMS support for IMS Emergency sessions** |  | 63.69d? | 2006-06-23 A | 2006-09-21 A | 100% | 2006-06-23 | 2006-09-21 | 63.69d? |  |  | S2 |  |  | IMS-EMER | Rel-7 | Maurice | Curt Wong (Nokia) | curt.c.wong@nokia.com | SP-30 |  |
| 340 | 84.1 | Deleted - IMS aspects to support IMS Emergency sessions | milestone | 0d? | 2006-06-23 A | 2006-09-21 A | 100% | 2006-06-23 | 2006-09-21 | 0d? |  | start no earlier than 2006-06-23 | S2 |  |  | IMS-EMER | Rel-7 | Maurice | Curt Wong (Nokia) | curt.c.wong@nokia.com | SP-30 | TSG |
| 341 | 84.2 | Deleted - PS domain aspects to support IMS Emergency sessions | milestone | 0d? | 2006-06-23 A | 2006-09-21 A | 100% | 2006-06-23 | 2006-09-21 | 0d? |  | start no earlier than 2006-06-23 | S2 |  |  | IMS-EMER | Rel-7 | Maurice | Curt Wong (Nokia) | curt.c.wong@nokia.com | SP-30 | TSG |
| 342 | 85 | Deleted - Covered by SI - Personal Network (PN) and Personal Area Network (PAN) | milestone | 0d? | 2005-12-08 A | 2005-12-20 A | 100% | 2005-12-08 | 2005-12-20 | 0d? |  | start no earlier than 2005-12-08 | S1 |  |  | PNPAN | Rel-7 | Mike | Armin Toepfer, Vodafone | armin.toepfer@vodafone.com | SP-30 |  |
| 343 | 86 | Deleted - Covered by SI - Multimedia Telephony Capabilities for IMS | milestone | 0d? | 2005-12-08 A | 2005-12-20 A | 100% | 2005-12-08 | 2005-12-20 | 0d? |  | start no earlier than 2005-12-08 | S1 |  |  | MITE | Rel-7 | Mike | Peter Bleckert, Ericsson | peter.bleckert @ericsson.com | SP-30 |  |
| 344 | 87 | Deleted - Covered by SI - Transferring of emergency Call data | milestone | 0d? | 2005-12-08 A | 2005-12-08 A | 100% | 2005-12-08 | 2005-12-08 | 0d? |  | start no earlier than 2005-12-08 | S1 |  |  | eCALL | Rel-7 | Mike | Steve Vardy, (Motorola S.A.S) | steven.vardy@motorola.com | SP-30 |  |
| 345 | 88 | Deleted - Covered by SI - MBMS Enhancements | milestone | 0d? | 2005-12-08 A | 2005-12-08 A | 100% | 2005-12-08 | 2005-12-08 | 0d? |  | start no earlier than 2005-12-08 | S1 |  |  | MBMSE | Rel-7 | Mike | Liu Hong, China Mobile | liuhongyfw@chinamobile.com | SP-30 |  |
| 346 | 89 | Deleted - GAN Enhancements | milestone | 0d? | 2007-08-31 A | 2007-08-31 A | 100% | 2006-11-17 | 2007-05-18 | 131d? |  | start no earlier than 2007-08-31 | GP |  |  | EGAN | Rel-8 | Paolo | Janne Linkola (T-Mobile) | janne.linkola@t-mobile.com | SP-38 |  |
| 347 | 90 | Deleted (moved to Rel8) - MS Antenna Performance Evaluation Method and Requirements | milestone | 0d? | 2005-01-28 A | 2005-01-28 A | 100% | 2005-01-28 | 2007-05-18 | 601d? |  | finish no earlier than 2005-01-28 | G1 |  |  | APEMR | Rel-7 | Paolo | Ulf.Tegth (TeliaSonera) | Ulf.Tegth@teliasonera.com | SP-38 | TSG |
| 348 | 91 | Deleted (moved to Rel8) - MBSFN Downlink Optimised Broadcast 3.84 Mcps TDD | milestone | 0d? | 2007-09-17 A | 2007-09-17 A | 100% |  |  |  |  | start no earlier than 2007-09-17 | R1 |  |  | MBSFN-DOB | Rel-7 | MCC_RAN | Lars Lindbom (Ericsson) |  | SP-38 |  |
| 349 | 92 | Deleted (moved to Rel-8) - Access Security Enhancements |  | 195d? | 2005-09-30 A | 2006-06-30 A | 100% | 2005-01-03 | 2005-09-30 | 195d? |  | finish no earlier than 2005-09-30 | S3 | 1560h | 1560h | ACCSEC2 | Rel-7 | Michael | Bengt Sahlin, Ericsson | Bengt.Sahlin@ericsson.com | SP-38 | TSG |
| 350 | 93 | Rel-7 Feasibility Studies |  | 1d? | 2000-01-03 | 2000-01-03 |  | 2000-01-03 | 2000-01-03 | 1d? | 2319d |  | CT,RAN,SA | 8h |  |  | Rel-7 |  |  |  |  |  |
| 351 | 94 | **(FS on) Multimedia Telephony Capabilities for IMS** |  | 276d? | 2005-07-11 A | 2006-07-31 A | 100% | 2005-07-11 | 2006-09-29 | 320d? |  |  | S1 | 4353.6h | 4353.6h | MITE | Rel-7 | Mike | Peter Bleckert, Ericsson | peter.bleckert @ericsson.com |  |  |
| 352 | 94.1 | Study of (MITe) - IMS Multimedia Telephony Communication Enabler and supplementary services |  | 276d? | 2005-07-11 A | 2006-07-31 A | 100% | 2005-07-11 | 2006-07-31 | 276d? |  | start no earlier than 2005-07-11 | S1 | 2208h | 2208h | MITE | Rel-7 | Mike | Peter Bleckert, Ericsson | peter.bleckert @ericsson.com |  |  |
| 353 | 95 | Abandonned - FS on IMS enhancements and optimisations for real time communication. |  | 430d? | 2005-10-10 A | 2007-06-01 A | 100% | 2005-10-10 | 2007-06-01 | 430d? |  | finish no earlier than 2007-06-01 | S2 | 3440h | 3440h | IMS-RT | Rel-7 | Maurice | Stephen Terrill (Ericsson) | stephen.terrill@ericsson.com |  |  |
| 354 | 96 | Deleted - Study of Personal Network and Personal Area Network | milestone | 0d? | 2006-10-20 A | 2006-10-20 A | 100% | 2005-07-11 | 2006-02-28 | 167d? |  | finish no earlier than 2006-10-20 | S1 |  |  | PNPAN | Rel-7 |  |  |  |  |  |
| 355 | 97 | (FS on) Behaviour of Multi system UEs |  | 384d? | 2004-06-28 A | 2005-12-15 A | 100% | 2004-06-28 | 2006-04-28 | 480d? |  | start no earlier than 2004-06-28 | S1 | 3072h | 3072h | BMSU | Rel-7 | Michael | D Williams (QUALCOMM) | dwilliams@qualcomm.com |  | TSG |
| 356 | 98 | **FS on IMS with real time services deployment** |  | 384d? | 2004-06-28 A | 2005-12-15 A | 100% | 2004-06-28 | 2005-12-15 | 384d? |  |  | S1 | 8672h | 8672h | IRTSD | Rel-7 | Maurice |  |  |  | TSG |
| 357 | 98.1 | Feasibility Study on Combining CS calls and IMS sessions |  | 384d? | 2004-06-28 A | 2005-12-15 A | 100% | 2004-06-28 | 2005-12-15 | 384d? |  | start no earlier than 2004-06-28 | S1 | 3072h | 3072h | IRTSD-CS_IMS | Rel-7 | Michael |  |  |  | TSG |
| 358 | 98.2 | TR on Stage 2 (IMS services using CS bearers) |  | 316d? | 2004-06-28 A | 2005-09-12 A | 100% | 2004-06-28 | 2005-09-12 | 316d? |  | finish no earlier than 2005-09-12 | S2 | 2528h | 2528h | IRTSD-IMSCS | Rel-7 | Maurice | Mark Watson (Nortel Networks) |  |  | TSG |
| 359 | 99 | (FS on) Terminating Session handling |  | 255d? | 2006-01-09 A | 2006-12-29 A | 100% | 2006-01-09 | 2006-12-29 | 255d? |  | finish no earlier than 2006-12-29 | S2 | 2040h | 2040h | CSIterm | Rel-7 | Maurice | Osok Song (Samsung) | osok.song@samsung.com |  |  |
| 360 | 100 | FS on Performance Evaluation of the UE behaviour in high speed trains with speeds up to 350 kmph |  | 328d? | 2005-03-15 A | 2006-06-15 A | 100% | 2005-03-15 | 2006-06-15 | 328d? |  | finish no earlier than 2006-06-15 | R4 | 2624h | 2624h | RANFS-HSTrains | Rel-7 | MCC_RAN | Mike Vogel | Mike.vogel@vodafone.com |  | TSG |
| 361 | 101 | FS on Evolved UTRA and UTRAN |  | 458d? | 2004-12-15 A | 2006-09-15 A | 100% | 2004-12-15 | 2006-09-15 | 458d? |  | finish no earlier than 2006-09-15 | RP | 3664h | 3664h | RANFS-Evo | Rel-7 | MCC_RAN | Takehiro Nakamura (NTT DoCoMo) | nakamurata@NTTDOCOMO.CO.JP |  | TSG |

Notes:
- 336: Text3: 22.173
- 337: Text3: 23.406, 23.417, 23.508,23.509, 23.511
- 338: Text3: CP-070260
- 339: Approved at SP#29 / Text3: 23.867, TS 23.abc, 23.060, 23.002, 23.271
- 340: Approved at SP#29 / Text3: 23.867, TS 23.abc, 23.060, 23.002, 23.271
- 341: Approved at SP#29 / Text3: 23.867, TS 23.abc, 23.060, 23.002, 23.271
- 346: Text3: 43.902
- 347: Moved to Rel-8 / Text3: 25.914, 25.944, 45.005
- 348: new WI / Text3: 25.346, 25.201,25.221,25.222,25.223,25.306,25.331,25.402,25.433,25.102,25.105,25.123
- 349: WID approved SA#26. Record created after SA#27. It is about improved GERAN security / Text3: 33.102, 43.020
- 351: Moved from FS section Feb 06
- 352: Text3: 22.973
- 353: Abandonned at 65% / Text3: 23.818
- 354: Moved from FS section Feb 06
- 355: The WID still calls it a BB, not a Feature. / Text3: 22.936
- 357: Text3: 22.979, 23.899
- 358: Text3: 23.899
- 359: S2#52: Split into Study and Specification phases. / Text3: 23.819

| ID | WBS | Task | Type | Duration | Start | Finish | Complete | Baseline start | Baseline finish | Baseline duration | Constraint | Resources | Work | Actual work | Text1 | Text4 | Text5 | Text6 | Text7 | Text8 | Text3 | Text12 |
| --- | --- | --- | --- | --- | --- | --- | --- | --- | --- | --- | --- | --- | --- | --- | --- | --- | --- | --- | --- | --- | --- | --- |
| 362 | 102 | **Study on Videotelephony teleservice** |  | 231d? | 2005-03-01 A | 2006-01-17 A | 100% | 2005-03-01 | 2006-01-17 | 231d? |  | S1 | 3696h | 3696h | VidTel | Kurt Bischinger (T-Mobile) | kurt.bischinger@t-mobile.at | Rel-7 | TSG | Michael |  |  |
| 363 | 102.1 | Study on Videotelephony service requirements |  | 231d? | 2005-03-01 A | 2006-01-17 A | 100% | 2005-03-01 | 2006-01-17 | 231d? | start no earlier than 2005-03-01 | S1 | 1848h | 1848h | VidTel | Kurt Bischinger (T-Mobile) | kurt.bischinger@t-mobile.at | Rel-7 | TSG | Michael | 22.903 |  |
| 364 | 103 | **Study of Network Selection Principles** |  | 193d? | 2005-03-15 A | 2005-12-08 A | 100% | 2005-03-15 | 2005-12-08 | 193d? |  | S1 | 3088h | 3088h | NetSel | Chris Friel (O2) | chris.friel@o2.com | Rel-7 | TSG | Michael |  |  |
| 365 | 103.1 | Review of Network Selection Principles |  | 193d? | 2005-03-15 A | 2005-12-08 A | 100% | 2005-03-15 | 2005-12-08 | 193d? | finish no earlier than 2005-12-08 | S1 | 1544h | 1544h | NetSel | Chris Friel (O2) | chris.friel@o2.com | Rel-7 | TSG | Michael | 22.811 |  |
| 366 | 104 | FS on Continuous connectivity for packet data users |  | 132d? | 2005-03-15 A | 2005-09-15 A | 100% | 2005-03-15 | 2005-09-15 | 132d? | finish no earlier than 2005-09-15 | R1 | 1056h | 1056h | RANFS-cont-packet | Joerg Gustrau | joerg.gustrau@siemens.com | Rel-7 | TSG | MCC_RAN |  |  |
| 367 | 105 | FS on UTRA Tower Mounted Amplifier (FDD) |  | 195d? | 2005-06-15 A | 2006-03-14 A | 100% | 2005-06-15 | 2006-03-14 | 195d? | finish no earlier than 2006-03-15 | R4 | 1560h | 1560h | RANFS-TMA | Klas Sjerling | Klas.Sjerling@ericsson.com | Rel-7 | TSG | MCC_RAN |  |  |
| 368 | 106 | (FS on) Multimedia Priority Service |  | 851d? | 2003-03-28 A | 2006-06-30 A | 100% | 2003-03-28 | 2006-06-30 | 851d? | finish no earlier than 2005-12-16 | S1 | 6808h | 6808h | PRIOR-MM | Jim Garrahan (Telcordia) | jgarraha@telcordia.com | Rel-7 |  | Michael | 22.953 |  |
| 369 | 107 | (FS on) Transferring of emergency Call data |  | 190d? | 2005-07-11 A | 2006-03-31 A | 100% | 2005-07-11 | 2006-03-31 | 190d? | finish no earlier than 2005-12-08 | S1 | 1520h | 1520h | eCALL | Steve Vardy, (Motorola S.A.S) | steven.vardy@motorola.com | Rel-7 |  | Mike | 22.967 |  |
| 370 | 108 | FS on Routeing of MT-SMs via the HPLMN |  | 301d? | 2005-10-07 A | 2006-12-01 A | 100% | 2005-10-07 | 2006-12-01 | 301d? | finish no earlier than 2006-12-01 | C4 | 2408h | 2408h | SMS7 | Nick Russell, Vodafone UK | Nick.Russell@vodafone.com | Rel-7 |  | Kimmo | 23.840 |  |
| 371 | 109 | FS on Improvement of the Multimedia Broadcast Multicast Service (MBMS) in UTRAN |  | 262d? | 2005-12-15 A | 2006-12-15 A | 100% | 2005-12-15 | 2006-12-15 | 262d? | finish no earlier than 2006-12-15 | R2 | 2096h | 2096h | RANFS-MBMSImp | YoungDae Lee, LG | leego@lge.com | Rel-7 |  | MCC_RAN |  |  |
| 372 | 110 | FS on Performance Improvements in Small Cells using HSDPA/EDCH |  | 131d? | 2005-12-15 A | 2006-06-15 A | 100% | 2005-12-15 | 2006-06-15 | 131d? | finish no earlier than 2006-06-15 | R4 | 1048h | 1048h | SMALLCELLS | Marc Grant, Cingular | marc.grant@cingular.com | Rel-7 |  | MCC_RAN |  |  |
| 373 | 111 | FS on Further Improved Performance Requirements for UMTS/HSDPA UE (FDD) |  | 383d? | 2005-12-15 A | 2007-06-04 A | 100% | 2005-12-15 | 2007-06-04 | 383d? | finish no earlier than 2007-06-04 | R4 | 3064h | 3064h | RANFS-IC | Marc Grant, Cingular | marc.grant@cingular.com | Rel-7 |  | MCC_RAN |  |  |
| 374 | 112 | FS on the TCAPsec Gateway concept |  | 96d? | 2005-10-28 A | 2006-03-10 A | 100% | 2005-10-28 | 2006-03-10 | 96d? | finish no earlier than 2006-03-10 | C4 | 768h | 768h | SEC7-TCAP | Ulrich Wiehe, Siemens | Ulrich.wiehe@gksag.de | Rel-7 |  | Kimmo | 29.800 |  |
| 375 | 113 | Study of Customised Alerting Tone (CAT) Requirements |  | 245d? | 2005-10-07 A | 2006-09-14 A | 100% | 2005-10-07 | 2006-06-30 | 191d? | start no earlier than 2005-10-07 | S1 | 1960h | 1960h | CAT | Feng Lingjuan, China Mobile | fenglingjuan@chinamobile.com | Rel-7 |  | Michael | 22.982 |  |
| 376 | 114 | SI on Scope of future FDD HSPA Evolution |  | 394d? | 2006-03-15 A | 2007-09-17 A | 100% | 2006-03-15 | 2007-06-04 | 319d? | finish no earlier than 2007-09-17 | RP | 3152h | 3152h | RANFS-HSPAEvo | Don Zelmer | don.zelmer@cingular.com | Rel-7 |  | MCC_RAN |  |  |
| 377 | 115 | **OAM&P Studies** |  | 400d? | 2005-09-02 A | 2007-03-15 A | 100% | 2005-09-02 | 2007-03-15 | 400d? |  | S5 | 14880h | 14880h | OAM-Study | Toche | Christian.Toche@huawei.com | Rel-7 | TSG | Adrian |  |  |
| 378 | 115.1 | Study of SOAP/HTTP IRP Solution Sets |  | 330d? | 2005-09-02 A | 2006-12-07 A | 100% | 2005-09-02 | 2006-12-07 | 330d? | finish no earlier than 2006-12-07 | S5 | 2640h | 2640h | OAM-Study | Nortel |  | Rel-7 |  |  | TR 32.809 | SP-32 |
| 379 | 115.2 | Study of Itf-N Implementation Conformance Statement (ICS) template |  | 400d? | 2005-09-02 A | 2007-03-15 A | 100% | 2005-09-02 | 2007-03-15 | 400d? | finish no earlier than 2007-03-15 | S5 | 3200h | 3200h | OAM-Study | China Mobile |  | Rel-7 |  |  | TR 32.812 | SP-32 |
| 380 | 115.3 | Study of IRP Information Model |  | 400d? | 2005-09-02 A | 2007-03-15 A | 100% | 2005-09-02 | 2007-03-15 | 400d? | finish no earlier than 2007-03-15 | S5 | 3200h | 3200h | OAM-Study | Motorola |  | Rel-7 |  |  | TR 32.810 | SP-32 |
| 381 | 115.4 | Stopped - Study on IRP usage scenarios |  | 330d? | 2005-09-02 A | 2006-12-07 A | 100% | 2005-09-02 | 2006-12-07 | 330d? | finish no earlier than 2006-12-07 | S5 | 2640h | 2640h | OAM-Study | Lucent |  | Rel-7 |  |  | new TR 32.8xy | SP-32 |
| 382 | 115.5 | **Deleted - Network Infrastructure Management** |  | 0d? | 2006-12-15 A | 2006-12-15 A | 100% | 2006-12-15 | 2006-12-15 | 0d? |  | S5 |  |  | OAM7-NIM |  |  | Rel-7 |  |  |  | SP-32 |
| 383 | 115.5.1 | Deleted - was duplicated - Study on SA5 MTOSI XML Harmonization | milestone | 0d? | 2006-12-15 A | 2006-12-15 A | 100% | 2006-12-15 | 2006-12-15 | 0d? | start no earlier than 2006-12-15 | S5 |  |  | OAM7-NIM-XML | Nortel |  | Rel-7 |  |  | new TR 32.8xy | SP-30 |
| 384 | 116 | FS of using M2PA in 3GPP network |  | 318d? | 2006-03-22 A | 2007-06-08 A | 100% | 2006-03-22 | 2007-06-08 | 318d? | finish no earlier than 2007-06-08 | C4 | 2544h | 2544h | FS-M2PA | Zhao Yuyi | zhaoyuyi@chinamobile.com | Rel-7 |  | Kimmo |  |  |
| 385 | 117 | (FS on) Enhancement of E2E QoS |  | 336.4d? | 2004-06-28 A | 2005-12-01 A | 100% | 2004-06-28 | 2005-12-01 | 336.4d? | finish no earlier than 2005-12-01 | S2 | 2691.2h | 2691.2h | QoS7 |  |  | Rel-7 | TSG | Maurice | 23.802 |  |
| 386 | 118 | FS on Bandwidth Saving at Nb Interface with IP transport |  | 261d? | 2006-03-10 A | 2007-03-09 A | 100% | 2006-03-10 | 2007-03-09 | 261d? | finish no earlier than 2007-03-09 | C3 | 2088h | 2088h | BSNbIP | Thomas BELLING(Siemens) | thomas.belling@siemens.com | Rel-7 |  | Seung Don | new TR 29.814 |  |

Notes:
- 368: Moved from Rel6, "FS on" added by MCC to distinguish from actual feature
- 370: Previously known as "Study of a SMS Centre for MT SMS"
- 371: Completed at RP#34 as RP-060692
- 374: Study WI...
- 375: Awaiting MCC SA3 input; No input from SA3 at this time
- 385: Moved to a FS as SA32 (in line with slides)
- 386: Moved to FS at CT32 (in line with slides)

| ID | WBS | Task | Type | Duration | Start | Finish | Complete | Baseline start | Baseline finish | Baseline duration | Constraint | Resources | Work | Actual work | Text1 | Text3 | Text4 | Text5 | Text6 | Text8 | Text12 | Text7 |
| --- | --- | --- | --- | --- | --- | --- | --- | --- | --- | --- | --- | --- | --- | --- | --- | --- | --- | --- | --- | --- | --- | --- |
| 387 | 119 | **FS on Support of (G)MSC-S - (G)MSC-S Nc Interface based on the SIP-I protocol** |  | 350d? | 2006-05-15 A | 2007-09-14 A | 100% | 2006-05-15 | 2007-06-01 | 275d? |  | C4 | 7800h | 7800h | NcSIP | 29.802 | David Hutton, Vodafone Group | david.hutton@vodafone.com | Rel-7 | Kimmo |  |  |
| 388 | 119.1 | CT4 aspects of NcSIP |  | 275d? | 2006-05-15 A | 2007-06-01 A | 100% | 2006-05-15 | 2007-06-01 | 275d? | finish no earlier than 2007-06-01 | C4 | 2200h | 2200h | NcSIP | 29.802 |  |  | Rel-7 |  |  |  |
| 389 | 119.2 | CT3 aspects of NcSIP |  | 350d? | 2006-05-15 A | 2007-09-14 A | 100% | 2006-05-15 | 2006-12-15 | 155d? | finish no earlier than 2007-09-14 | C3 | 2800h | 2800h | NcSIP |  | Ragnar Huslende, Ericsson | ragnar.huslende@ericsson.com | Rel-7 |  |  |  |
| 390 | 120 | **Study on Dynamically reconfiguring a FDD UE receiver to reduce power consumption when desired Quality of Service is met** |  | 256d? | 2006-09-25 A | 2007-09-17 A | 100% | 2006-09-25 | 2007-06-04 | 181d? |  | RP | 4096h | 4096h | FSUEPow | 25.xxx | Chris Callender, Nokia | Chris.callender@nokia.com | Rel-7 | MCC_RAN |  |  |
| 391 | 120.1 | RAN4 aspects of FSUEPow |  | 256d? | 2006-09-25 A | 2007-09-17 A | 100% | 2006-09-25 | 2007-06-04 | 181d? | finish no earlier than 2007-09-17 | R4 | 2048h | 2048h | RANFS-UEPow |  | Tiina Koskinen (Nokia) | tiina.s.koskinen@nokia.com | Rel-7 | MCC_RAN |  |  |
| 392 | 120.2 | Deleted - RAN2 aspects of FSUEPow | milestone | 0d? | 2007-06-22 A | 2007-06-22 A | 100% | 2006-09-25 | 2007-06-04 | 181d? | start no earlier than 2007-06-22 | R2 |  |  | FSUEPow |  | Tiina Koskinen (Nokia) | tiina.s.koskinen@nokia.com | Rel-7 | MCC_RAN |  |  |
| 393 | 121 | FS on 3G Home NodeB/eNodeB |  | 140d? | 2007-03-05 A | 2007-09-14 A | 100% | 2007-03-05 | 2007-12-21 | 210d? | finish no earlier than 2007-12-21 | R4 | 1120h | 1120h | RANFS-HNBeNB | TR 25.820 | Howard Thomas (Motorola) | howard.thomas@motorola.com | Rel-7 | Claude |  |  |
| 394 | 122 | deleted - covered by UID33027 - IMS security extensions | milestone | 0d? | 2005-12-08 A | 2005-12-08 A | 100% | 2005-12-08 | 2005-12-08 | 0d? | start no earlier than 2005-12-08 | S3 |  |  | IMS-SE |  | Bengt Sahlin, Ericsson | Bengt.Sahlin@ericsson.com | Rel-7 | Mike | SP-30 |  |
| 395 | 123 | Deleted - covered by 32108 - Study of work on an LCS architecture for I-WLAN | milestone | 0d? | 2006-12-08 A | 2006-12-08 A | 100% | 2006-12-08 | 2006-12-08 | 0d? | start no earlier than 2006-12-08 | S2 |  |  | IMS-SE |  | Donghee Shim (LG Electronics Inc.) | dhshim@lge.com ; phede@lge.com | Rel-7 | Maurice | SP-33 |  |
| 396 | 124 | **Deleted: FS on applicability of GALILEO for LCS** |  | 0d? | 2005-06-30 A | 2005-06-30 A | 100% | 2005-06-30 | 2005-06-30 | 0d? |  | S2 |  |  | Galileo |  |  |  | Rel-7 |  | SP-25 |  |
| 397 | 124.1 | Deleted - TR on Stage 2 | milestone | 0d? | 2005-06-30 A | 2005-06-30 A | 100% | 2005-06-30 | 2005-06-30 | 0d? | finish no earlier than 2005-06-30 | S2 |  |  | Galileo |  |  |  | Rel-7 |  | SP-25 |  |
| 398 | 124.2 | deleted - GERAN review of the TR | milestone | 0d? | 2005-06-30 A | 2005-06-30 A | 100% | 2005-06-30 | 2005-06-30 | 0d? | start no earlier than 2005-06-30 | GP |  |  | Galileo |  |  |  | Rel-7 |  | SP-26 |  |
| 399 | 16.7 | **Deleted - IMS Local services** |  | 0d? | 2006-01-06 A | 2006-01-06 A | 100% | 2006-01-06 | 2006-01-06 | 0d? |  | S2 |  |  | IMSLocal | 23.228 |  |  | Rel-7 |  | SP-28 |  |
| 400 | 16.7.1 | Deleted - Stage 2 | milestone | 0d | 2006-01-06 A | 2006-01-06 A | 100% | 2006-01-06 | 2006-01-06 | 0d | start no earlier than 2006-01-06 | S2 |  |  | IMSLocal |  |  |  | Rel-7 |  | SP-26 |  |
| 401 | 125.2 | Delete - Stage 3 for IMS Local services | milestone | 0d? | 2006-01-06 A | 2006-01-06 A | 100% | 2006-01-06 | 2006-01-06 | 0d? | finish no earlier than 2006-01-06 | C1 |  |  | IMSLocal |  | Keith Drage, Lucent | drage@lucent.com | Rel-7 |  | SP-25 |  |
| 402 | 126 | Deleted - IMS Phase 3 | milestone | 0d? | 2006-01-06 A | 2006-01-06 A | 100% | 2006-01-06 | 2006-01-06 | 0d? | start no earlier than 2006-01-06 | S2 |  |  |  |  |  |  | Rel-7 |  | SP-25 |  |
| 403 | 127 | Deleted - Improvements of Radio Interface | milestone | 0d? | 2004-09-15 A | 2004-09-15 A | 100% | 2004-09-15 | 2004-09-15 | 0d? | start no earlier than 2004-09-15 | RP |  |  | RInImp |  |  | Rel-7 | Rel-7 | Claude | SP-24 | TSG |
| 404 | 128 | Deleted: Generic User Profile Phase 2 | milestone | 0d | 2005-08-08 A | 2006-06-30 A | 100% | 2005-08-08 | 2006-06-30 | 0d |  | C4 |  |  |  |  |  |  | Rel-7 | Gaby | SP-27 |  |
| 405 | 30.4 | Deleted - Stage 3 - Common objects | milestone | 0d | 2005-08-08 A | 2006-06-30 A | 100% | 2005-08-08 | 2006-06-30 | 0d | finish no earlier than 2006-06-30 | C4 |  |  |  | 24.241 |  |  | Rel-7 | Gaby | SP-27 | TSG |
| 406 | 130 | Delete was duplicated- Study of Customised Alerting Tone (CAT) Requirements | milestone | 0d? | 2006-06-30 A | 2006-06-30 A | 100% | 2006-06-30 | 2006-06-30 | 0d? | start no earlier than 2006-06-30 | S1 |  |  | CAT |  |  |  | Rel-7 |  | SP-31 |  |
| 407 | 131 | Delete - was duplicated - Facilitating Machine to Machine Communication in GSM and UMTS (M2M) | milestone | 0d? | 2006-06-30 A | 2006-06-30 A | 100% | 2006-06-30 | 2006-06-30 | 0d? | start no earlier than 2006-06-30 | S1 |  |  | M2M | 22.868 | Juergen Merkel, Siemens AG |  | Rel-7 | Michael | SP-32 |  |
| 408 | 132 | Deleted - FS of enhanced support of Video Telephony | milestone | 0d? | 2006-06-30 A | 2006-06-30 A | 100% | 2006-06-30 | 2006-06-30 | 0d? | start no earlier than 2006-06-30 | GP |  |  | VIDGER |  | Stefan Eriksson, Ericsson | stefan.g.eriksson@ericsson.com | Rel-7 | Paolo | SP-32 | TSG |
| 409 | 133 | Deleted (moved to Rel8) - FS on Transferring of emergency call data – in-band modem solution | milestone | 0d? | 2007-06-22 A | 2007-06-22 A | 100% | 2006-12-07 | 2007-06-07 | 131d? | start no earlier than 2007-06-22 | S4 |  |  | eCALLIBMS | 26.967 | Leon Hong, Airbiquity | lhong@airbiquity.com | Rel-7 | Paolo | SP-38 |  |
| 410 | 134 | Deleted (moved to Rel-8) - U-TDOA Enhancement | milestone | 0d? | 2007-05-18 A | 2007-05-18 A | 100% |  |  |  | finish no earlier than 2007-05-18 | GP |  |  | GUTEN | 43.059, 45.008, 48.071 | Terri L. Brooks (TruePosition, Inc.) | terri.brooks@trueposition.com | Rel-8 | Paolo | SP-38 |  |

Notes:
- 387: Study WI
- 393: Finally kept in Rel-7 after having been moved to Rel-8
- 395: S2#52: Entry created
- 400: DAB - Not yet required in SA2 as it exists in previous releases
- 403: Stage 2 description of Interim conclusion
- 404: Created at TSG#27 by A. Sultan because of the move to Rel-7 of "Common Objects".
- 405: No progress in CN4#26. This have to be moved to Rel-7. It was deleted from WID
- 406: Awaiting MCC SA3 input
- 408: FS CLOSED at G#28 (no input)
- 409: Not completed
- 410: Moved to Rel-8

| ID | WBS | Task | Type | Duration | Start | Finish | Complete | Baseline start | Baseline finish | Baseline duration | Constraint | Resources | Work | Actual work | Text1 | Text6 | Text7 | Text12 | Text3 | Text4 | Text8 | Text5 |
| --- | --- | --- | --- | --- | --- | --- | --- | --- | --- | --- | --- | --- | --- | --- | --- | --- | --- | --- | --- | --- | --- | --- |
| 411 | 135 | **Deleted (moved to Rel8) - FS on 3GPP System Architecture Evolution** |  | 262d? | 2006-09-27 A | 2007-09-28 A | 100% | 2004-12-03 | 2007-09-28 | 736d? |  | S2 | 2096h | 2096h | SAE | Rel-7 | TSG | SP-38 |  |  |  |  |
| 412 | 135.1 | Deleted (moved to Rel8) - Stage 2 Interim conclusion for RAN Work to start | milestone | 0d? | 2007-09-28 A | 2007-09-28 A | 100% | 2004-12-03 | 2005-09-23 | 211d? | start no earlier than 2007-09-28 | S2 |  |  | SAE | Rel-7 |  | SP-38 | 23.882 |  |  |  |
| 413 | 135.2 | Deleted (moved to Rel8) - Stage 2 Feasibility study on 3GPP architectural development | milestone | 0d? | 2007-09-28 A | 2007-09-28 A | 100% | 2006-01-09 | 2007-09-28 | 450d? | start no earlier than 2007-09-28 | S2 |  |  | SAE | Rel-7 |  | SP-38 | 23.882 | Chris Pudney | Maurice |  |
| 414 | 135.3 | Deleted (moved to Rel8) - Security study for Inter-access mobility between non 3GPP and 3GPP system | milestone | 0d? | 2007-09-28 A | 2007-09-28 A | 100% | 2006-02-03 | 2006-06-02 | 86d? | start no earlier than 2007-09-28 | S3 |  |  | SAE-Sec | Rel-7 |  | SP-38 | 23.882, 33.821, 33.922 | Dajiang Zhang (Nokia) |  | dajiang.zhang@NOKIA.COM |
| 415 | 135.4 | Deleted - Duplicateed with 32087 - Stage 2 Feasibility study on 3GPP architectural development | milestone | 0d? | 2006-09-27 A | 2006-09-27 A | 100% | 2006-09-27 | 2006-09-27 | 0d? | start no earlier than 2006-09-27 | S2 |  |  | SAE | Rel-7 |  | SP-32 | 23.882 |  |  |  |
| 416 | 136 | deleted - covered by UID 20053 - FS on Interference Cancellation for UTRA FDD UE |  | 1d? | 2007-03-28 A | 2007-03-28 A | 100% |  |  |  | start no earlier than 2007-03-28 | R4 | 8h | 8h | RANFS-InterfCanc | Rel-7 |  | SP-38 |  |  |  |  |

Notes:
- 412: RAN work started
- 413: Some items left SR VCC, Local Breakout, Network Access Selection
- 416: Deleted. Same as FS on Further Improved Performance Requirements for UMTS/HSDPA UE (FDD)
